# 120123_unconventional gas gantt chart

Schedule from MS Project, 2012-02-27 to 2037-03-23.
Formerly 000497.rachel.maiden.mpp / Formerly 000626.rachel.maiden.maiden / Formerly 000327.bianca.gregory.maiden
Department of Mines and Petroleum
FileNo=A1181/201101<!>Site=Perth<!>MDNo=<!>DocType=Other<!>DocSec=Unconventional Gas Working Group<!>Owner=rachel.maiden<!>Filename=000808.rachel.maiden.maiden<!>Project=<!>Group=Approvals<!>SecType=Departmental Use Only

## Calendars

- Standard: Mon-Fri 08:00-12:00, 13:00-17:00; Sat-Sun off.

## Resources

| Resource |
| --- |
| DMP PEG |
| DEC |
| EPA |
| Fisheries |
| NT |
| DMP/NNTT |
| Proponent |
| DMP PD |
| DMP PTLAB |
| Resources Branch |
| Environment Division |
| Petroleum Tenure and Land Access Branch |
| http://www.dmp.wa.gov.au/1695.aspx |
| ED P |
| DOW |
| OEPA |
| DMP ED |
| DMP MTD |
| PD |
| DMP RSD |
| DIA |
| Proponent/Landgate |
| DMP |

## Schedule

| ID | WBS | Task | Type | Duration | Start | Finish | Predecessors | Total slack | Free slack | Constraint | Resources | Work | Text1 |
| --- | --- | --- | --- | --- | --- | --- | --- | --- | --- | --- | --- | --- | --- |
| 1 | 1 | **EXPLORATION TENURE APPROVALS** |  | 418d | 2013-02-27 | 2014-10-03 |  |  |  |  | http://www.dmp.wa.gov.au/1695.aspx | 11792h |  |
| 2 | 1.1 | **Acreage Release (PGERA67)** |  | 182d | 2013-02-27 | 2013-11-07 |  | 0d |  |  |  | 1936h |  |
| 3 | 1.1.1 | **Pre-gazette development** |  | 60d | 2013-02-27 | 2013-05-21 |  | 0d |  |  | DMP PD | 960h |  |
| 4 | 1.1.1.1 | Determine area, prepare maps of lease showing conservation estates, reserves, NT |  | 4w | 2013-02-27 | 2013-03-26 |  | 0d |  |  | DMP PD | 160h |  |
| 5 | 1.1.1.2 | Consultation with stakeholders |  | 4w | 2013-03-27 | 2013-04-23 | 4 | 0d |  |  | DMP PD | 160h |  |
| 6 | 1.1.1.3 | Preparation of Gazette notice |  | 4w | 2013-04-24 | 2013-05-21 | 5 | 0d |  |  | DMP PD | 160h |  |
| 7 | 1.1.2 | Publish Gazette Notice (s30) |  | 1d | 2013-05-22 | 2013-05-22 | 3 | 0d |  |  | DMP PD | 8h |  |
| 8 | 1.1.3 | Prepare bid |  | 6mo | 2013-05-23 | 2013-11-06 | 7 | 0d |  |  | Proponent | 960h |  |
| 9 | 1.1.4 | Lodge bid with DMP (s31) |  | 1d | 2013-11-07 | 2013-11-07 | 8 | 0d |  |  | Proponent | 8h |  |
| 10 | 1.2 | **Award of Exploration Permit (s38)** |  | 223d | 2013-11-08 | 2014-09-16 | 9 | 0d |  |  | DMP PD | 6264h |  |
| 11 | 1.2.1 | assessment of bids/applications |  | 3mo | 2013-11-08 | 2014-01-30 | 9 | 0d |  |  | DMP PD | 480h |  |
| 12 | 1.2.2 | bid assessment report |  | 4w | 2014-01-31 | 2014-02-27 | 11 | 0d |  |  | DMP PD | 160h |  |
| 13 | 1.2.3 | response to preferred applicant letter |  | 14d | 2014-02-28 | 2014-03-19 | 12 | 0d |  |  | Proponent | 112h |  |
| 14 | 1.2.4 | **Native Title Agreements** |  | 143d | 2014-02-28 | 2014-09-16 |  | 0d |  |  | DMP/NNTT | 3728h | http://www.dmp.wa.gov.au/487.aspx |
| 15 | 1.2.4.1 | Advertised (s29 NTA) |  | 120d | 2014-03-20 | 2014-09-03 | 13 | 22d | 0d |  | DMP PD | 960h | http://www.dmp.wa.gov.au/documents/StatePolicyFlowchart.pdf |
| 16 | 1.2.4.2 | Administration |  | 60d | 2014-03-20 | 2014-06-11 | 15SS, 17SS | 82d |  | start no earlier than 2010-09-17 | DMP/NNTT | 480h |  |
| 17 | 1.2.4.3 | "Right to Negotiate" |  | 125d | 2014-02-28 | 2014-08-21 | 13SS | 0d |  |  | DMP/NNTT | 1000h |  |
| 18 | 1.2.4.4 | State Deed (s31) |  | 18d | 2014-08-22 | 2014-09-16 | 17 | 13d |  |  | DMP PD | 144h |  |
| 19 | 1.3 | **Permit grant** |  | 31d | 2014-08-22 | 2014-10-03 |  | 0d |  |  |  | 248h |  |
| 20 | 1.3.1 | offer of grant |  | 30d | 2014-08-22 | 2014-10-02 | 13, 17 | 0d |  |  | DMP PD | 240h |  |
| 21 | 1.3.2 | award permit |  | 1d | 2014-10-03 | 2014-10-03 | 20 | 0d |  |  | DMP PD | 8h |  |
| 22 | 2 | **EXPLORATION** |  | 1030d | 2014-10-03 | 2018-09-14 | 21 | 30d |  |  |  | 17736h |  |
| 23 | 2.1 | **Activity Approval (Drilling)** |  | 90d | 2014-10-03 | 2015-02-06 |  | 999d |  |  |  | 1848h |  |
| 24 | 2.1.1 | Submit application | milestone | 0d | 2014-10-03 | 2014-10-03 | 21 | 999d | 0d |  | Proponent |  |  |
| 25 | 2.1.2 | Assess Technical Report |  | 30d | 2014-10-06 | 2014-11-14 | 24SS | 5830d |  |  | DMP PD | 240h |  |
| 26 | 2.1.3 | Assess Well Operation Management Plan (WOMP) and Drill Program |  | 30d | 2014-10-06 | 2014-11-14 | 24SS | 5830d |  |  | DMP PD | 240h |  |
| 27 | 2.1.4 | Assess Safety Management System |  | 20d | 2014-10-06 | 2014-10-31 | 24SS | 5840d |  |  | DMP RSD | 160h |  |
| 28 | 2.1.5 | Heritage Clearance |  | 30d | 2014-10-06 | 2014-11-14 | 21SS | 5830d |  |  | DIA | 240h |  |
| 29 | 2.1.6 | Access and Compensation Agreements |  | 90d | 2014-10-06 | 2015-02-06 | 21SS | 5770d |  |  | Proponent | 720h |  |
| 30 | 2.1.7 | Environment Plans |  | 30d | 2014-10-06 | 2014-11-14 | 24SS | 999d | 0d |  | DMP ED | 240h |  |
| 31 | 2.1.8 | Data submission |  | 1d | 2014-11-17 | 2014-11-17 | 30 | 5829d |  |  | Proponent | 8h |  |
| 32 | 2.2 | EXPLORATION ACTIVITY (seismic, drilling, interpreting data) | manual | 12mo | 2014-11-17 | 2015-10-16 | 30 |  |  |  | Proponent | 1920h |  |
| 33 | 2.3 | Licence to construct a well (s26d RIWA) |  | 30d | 2014-10-06 | 2014-11-14 | 21 | 5830d |  |  |  |  |  |
| 34 | 2.4 | Licence to Take water (s5c RIWA) |  | 60d | 2014-10-06 | 2014-12-26 | 21 | 5800d |  |  | DOW | 480h |  |
| 35 | 2.5 | Native Vegetation Clearing Approvals (schedule 6) (EP Act) |  | 60d | 2014-10-06 | 2014-12-26 | 21 | 5800d |  |  | DMP ED | 480h | http://www.dmp.wa.gov.au/819.aspx |

Notes:
- 1: NB: This process is used only if there is no existing tenure.
- 2: http://www.dmp.wa.gov.au/documents/PD-PTLA-POL-102D.pdf
- 10: http://www.dmp.wa.gov.au/1691.aspx
- 11: http://www.dmp.wa.gov.au/documents/EXPLORATION_PERMIT_APPLICATION_PROCESS_FLOWCHART_(WEB).pdf
- 17: this is an estimate only - times will vary depending on nature of agreements
- 18: this is an estimate only - times vary depending on signatories
- 22: *NB: projects may be referred at exploration through State or Federal environmental approval process
- 23: Required for each activity, batch approvals may be sought
- 29: this is an estimate only - times will vary depending on nature of agreements
- 30: may be referred under EPBC Act for Federal government assessment
- 31: proponent must submit resource data to DMP throughout activity
- 33: only required if company needs to drill water well for water supply
- 34: only if new water well or table

| ID | WBS | Task | Type | Duration | Start | Finish | Predecessors | Total slack | Free slack | Resources | Work |
| --- | --- | --- | --- | --- | --- | --- | --- | --- | --- | --- | --- |
| 36 | 2.6 | **Activity Approval (Fraccing)** |  | 30d | 2015-10-16 | 2015-11-27 | 32 | 5560d |  |  | 888h |
| 37 | 2.6.1 | Submit application | milestone | 0d | 2015-10-16 | 2015-10-16 | 32 | 5560d | 0d | Proponent |  |
| 38 | 2.6.2 | Assess Technical Report |  | 30d | 2015-10-19 | 2015-11-27 | 37SS | 5560d |  | DMP PD | 240h |
| 39 | 2.6.3 | Assess Well Operation Management Plan (WOMP) and Drill Program |  | 30d | 2015-10-19 | 2015-11-27 | 37SS | 5560d |  | DMP PD | 240h |
| 40 | 2.6.4 | Assess Safety Management System |  | 20d | 2015-10-19 | 2015-11-13 | 37SS | 5570d |  | DMP RSD | 160h |
| 41 | 2.6.5 | Environment Plans |  | 30d | 2015-10-19 | 2015-11-27 | 37SS | 5560d |  | DMP ED | 240h |
| 42 | 2.6.6 | Data submission |  | 1d | 2015-10-19 | 2015-10-19 |  | 5589d |  | Proponent | 8h |
| 43 | 2.7 | **Activity Approval (Completion)** |  | 30d | 2014-10-03 | 2014-11-14 |  | 5830d |  |  | 888h |
| 44 | 2.7.1 | Submit application | milestone | 0d | 2014-10-03 | 2014-10-03 |  | 5830d | 0d | Proponent |  |
| 45 | 2.7.2 | Assess Technical Report |  | 30d | 2014-10-06 | 2014-11-14 | 44SS | 5830d |  | DMP PD | 240h |
| 46 | 2.7.3 | Assess Well Operation Management Plan (WOMP) and Drill Program |  | 30d | 2014-10-06 | 2014-11-14 | 44SS | 5830d |  | DMP PD | 240h |
| 47 | 2.7.4 | Assess Safety Management System |  | 20d | 2014-10-06 | 2014-10-31 | 44SS | 5840d |  | DMP RSD | 160h |
| 48 | 2.7.5 | Environment Plans |  | 30d | 2014-10-06 | 2014-11-14 | 44SS | 5830d |  | DMP ED | 240h |
| 49 | 2.7.6 | Data submission |  | 1d | 2014-10-06 | 2014-10-06 |  | 5859d |  | Proponent | 8h |
| 50 | 2.8 | **EXPLORATION ACTIVITY** |  | 1000d | 2014-11-17 | 2018-09-14 | 30, 1 |  |  | Proponent | 8008h |
| 51 | 2.8.1 | Notice of Discovery |  | 1d | 2014-11-17 | 2014-11-17 |  | 999d | 0d | Proponent | 8h |
| 52 | 2.9 | **Extended Production Test (EPT)** |  | 212d | 2014-10-06 | 2015-07-28 |  | 4689d |  |  | 3224h |
| 53 | 2.9.1 | Submit application | milestone | 0d | 2014-11-17 | 2014-11-17 | 51 | 5799d | 0d | Proponent |  |
| 54 | 2.9.2 | Assess Technical Report |  | 30d | 2014-11-18 | 2014-12-29 | 53SS | 5799d |  | DMP PD | 240h |
| 55 | 2.9.3 | Assess Well Operation Management Plan (WOMP) and Drill Program |  | 30d | 2014-11-18 | 2014-12-29 | 53SS | 5799d |  | DMP PD | 240h |
| 56 | 2.9.4 | Assess Safety Management System |  | 20d | 2014-11-18 | 2014-12-15 | 53SS | 5809d |  | DMP RSD | 160h |
| 57 | 2.9.5 | Environment Plans |  | 30d | 2014-11-18 | 2014-12-29 | 53SS | 5799d |  | DMP ED | 240h |
| 58 | 2.9.6 | Data submission |  | 1d | 2014-10-06 | 2014-10-06 |  | 5859d |  | Proponent | 8h |
| 59 | 2.9.7 | **Declaration of Location** |  | 30d | 2014-11-18 | 2014-12-29 |  | 4658d |  |  | 240h |
| 60 | 2.9.7.1 | application and technical assessment |  | 30d | 2014-11-18 | 2014-12-29 | 51 | 4658d | 0d | DMP PD | 240h |

Notes:
- 36: Required for each activity, batch approvals may be sought
- 41: may be referred under EPBC Act for Federal government assessment
- 42: proponent must submit resource data to DMP throughout activity
- 43: Required for each activity, batch approvals may be sought
- 48: may be referred under EPBC Act for Federal government assessment
- 49: proponent must submit resource data to DMP throughout activity
- 57: may be referred under EPBC Act for Federal government assessment
- 58: proponent must submit resource data to DMP throughout activity
- 59: If not proceeding to production approvals, then retention approvals must be sought)
- 60: valid for up to 4 years (2 years plus 2 year renewal)

| ID | WBS | Task | Type | Duration | Start | Finish | Predecessors | Total slack | Free slack | Resources | Work |
| --- | --- | --- | --- | --- | --- | --- | --- | --- | --- | --- | --- |
| 61 | 2.9.8 | **Proof of Concept (Reservoir)** |  | 212d | 2014-10-06 | 2015-07-28 |  | 4869d |  |  | 2096h |
| 62 | 2.9.8.1 | Extended Production Testing |  | 6mo | 2014-12-30 | 2015-06-15 | 60 | 4808d | 0d | Proponent | 960h |
| 63 | 2.9.8.2 | Submit application |  | 1d | 2015-06-16 | 2015-06-16 | 62 | 4808d | 0d | Proponent | 8h |
| 64 | 2.9.8.3 | Preliminary Field Development Plan and Schedule |  | 30d | 2015-06-17 | 2015-07-28 | 63 | 5648d |  | DMP PD | 240h |
| 65 | 2.9.8.4 | Technical Report |  | 30d | 2015-06-17 | 2015-07-28 | 63 | 5648d |  | DMP PD | 240h |
| 66 | 2.9.8.5 | WOMP & Drill Program |  | 30d | 2015-06-17 | 2015-07-28 | 63 | 5648d |  | DMP PD | 240h |
| 67 | 2.9.8.6 | Environment Plans |  | 30d | 2015-06-17 | 2015-07-28 | 63 | 5648d |  | DMP ED | 240h |
| 68 | 2.9.8.7 | Safety Management System(re-entry) |  | 20d | 2015-06-17 | 2015-07-14 | 63 | 4808d | 0d | DMP RSD | 160h |
| 69 | 2.9.8.8 | Data submission |  | 1d | 2014-10-06 | 2014-10-06 |  | 5859d |  | Proponent | 8h |
| 70 | 3 | **PILOT APPROVALS** |  | 261d | 2014-12-30 | 2015-12-29 | 60 | 4808d | 0d |  | 5608h |
| 71 | 3.1 | **Activity Approval (Drilling)** |  | 90d | 2015-07-14 | 2015-11-17 | 68 | 4808d |  |  | 1608h |
| 72 | 3.1.1 | Submit application | milestone | 0d | 2015-07-14 | 2015-07-14 | 68 | 4808d | 0d | Proponent |  |
| 73 | 3.1.2 | Assess Technical Report |  | 30d | 2015-07-15 | 2015-08-25 | 72SS | 4898d |  | DMP PD | 240h |
| 74 | 3.1.3 | Assess Well Operation Management Plan (WOMP) and Drill Program |  | 30d | 2015-07-15 | 2015-08-25 | 72SS | 4898d |  | DMP PD | 240h |
| 75 | 3.1.4 | Assess Safety Management System |  | 20d | 2015-07-15 | 2015-08-11 | 72SS | 4908d |  | DMP RSD | 160h |
| 76 | 3.1.5 | Access and Compensation Agreements |  | 90d | 2015-07-15 | 2015-11-17 |  | 4838d |  | Proponent | 720h |
| 77 | 3.1.6 | Environment Plans |  | 30d | 2015-07-15 | 2015-08-25 | 72SS | 4808d | 0d | DMP ED | 240h |
| 78 | 3.1.7 | Data submission |  | 1d | 2015-07-15 | 2015-07-15 |  | 4927d |  | Proponent | 8h |
| 79 | 3.2 | **Activity Approval (Fraccing)** |  | 90d | 2015-08-25 | 2015-12-29 | 77 | 4808d |  |  | 1608h |
| 80 | 3.2.1 | Submit application | milestone | 0d | 2015-08-25 | 2015-08-25 | 77 | 4868d | 0d | Proponent |  |
| 81 | 3.2.2 | Assess Technical Report |  | 30d | 2015-08-26 | 2015-10-06 | 80SS | 4868d |  | DMP PD | 240h |
| 82 | 3.2.3 | Assess Well Operation Management Plan (WOMP) and Drill Program |  | 30d | 2015-08-26 | 2015-10-06 | 80SS | 4868d |  | DMP PD | 240h |
| 83 | 3.2.4 | Assess Safety Management System |  | 20d | 2015-08-26 | 2015-09-22 | 80SS | 4878d |  | DMP RSD | 160h |
| 84 | 3.2.5 | Access and Compensation Agreements |  | 90d | 2015-08-26 | 2015-12-29 |  | 4808d |  | Proponent | 720h |
| 85 | 3.2.6 | Environment Plans |  | 30d | 2015-08-26 | 2015-10-06 | 80SS | 4868d |  | DMP ED | 240h |
| 86 | 3.2.7 | Data submission |  | 1d | 2015-08-26 | 2015-08-26 |  | 4897d |  | Proponent | 8h |

Notes:
- 61: eg for stimulation activities not previously applied for
- 62: renewable, volume limits apply
- 67: may be referred under EPBC Act for Federal government assessment
- 69: proponent must submit resource data to DMP throughout activity
- 70: *NB: projects may be referred at pilot through State or Federal environmental approval process. See line 84 and 107
- 71: Required for each activity, batch approvals may be sought
- 76: this is an estimate only - times will vary depending on nature of agreements
- 77: may be referred under EPBC Act for Federal government assessment
- 78: proponent must submit resource data to DMP throughout activity
- 79: Required for each activity, batch approvals may be sought
- 84: this is an estimate only - times will vary depending on nature of agreements
- 85: may be referred under EPBC Act for Federal government assessment
- 86: proponent must submit resource data to DMP throughout activity

| ID | WBS | Task | Duration | Start | Finish | Predecessors | Total slack | Free slack | Constraint | Resources | Work | Text1 |
| --- | --- | --- | --- | --- | --- | --- | --- | --- | --- | --- | --- | --- |
| 87 | 3.3 | **Pipeline Licence (Petroleum Pipelines Act 1969) (s6)** | 91d | 2014-12-30 | 2015-05-05 |  | 4978d |  |  |  | 2392h |  |
| 88 | 3.3.1 | Submit application | 1d | 2014-12-30 | 2014-12-30 | 60 | 4978d | 0d |  | Proponent | 8h |  |
| 89 | 3.3.2 | advertised (ss8(4)) | 30d | 2014-12-30 | 2015-02-09 | 88SS | 5039d |  |  | DMP PD | 240h |  |
| 90 | 3.3.3 | notification (ss8(3)(b)) | 28d | 2014-12-30 | 2015-02-05 | 88SS | 5041d |  |  | Proponent | 224h |  |
| 91 | 3.3.4 | Acquire land tenure (Land Administration Act) | 30d | 2014-12-30 | 2015-02-09 | 88SS | 5039d |  |  | Proponent/Landgate | 240h |  |
| 92 | 3.3.5 | grant | 30d | 2014-12-31 | 2015-02-10 | 88 | 4978d | 0d |  | DMP PD | 240h |  |
| 93 | 3.3.6 | **approval to construct** | 30d | 2015-02-11 | 2015-03-24 |  | 4978d | 0d |  |  | 960h |  |
| 94 | 3.3.6.1 | Safety Management Case | 30d | 2015-02-11 | 2015-03-24 | 92 | 4978d |  |  | DMP RSD | 240h |  |
| 95 | 3.3.6.2 | Environment Plans | 30d | 2015-02-11 | 2015-03-24 | 92 | 4978d |  |  | DMP ED | 240h |  |
| 96 | 3.3.6.3 | Native Vegetation Clearing Approvals (schedule 6) (EP Act) | 30d | 2015-02-11 | 2015-03-24 | 92 | 4978d |  |  | DMP ED | 240h |  |
| 97 | 3.3.6.4 | Heritage Clearance | 30d | 2015-02-11 | 2015-03-24 | 92 | 4978d |  |  | DIA | 240h |  |
| 98 | 3.3.7 | **Approval to operate (s36)** | 30d | 2015-03-25 | 2015-05-05 |  | 4978d |  |  |  | 480h |  |
| 99 | 3.3.7.1 | Safety Management Case | 30d | 2015-03-25 | 2015-05-05 | 93 | 4978d |  |  | DMP RSD | 240h |  |
| 100 | 3.3.7.2 | Environment Plans | 30d | 2015-03-25 | 2015-05-05 | 93 | 4978d | 170d |  | DMP PD | 240h |  |
| 101 | 4 | PILOT ACTIVITY | 730d | 2015-12-30 | 2018-10-16 | 100, 70 | 4808d |  |  | Proponent | 5840h |  |
| 102 | 5 | **PRODUCTION APPROVALS** | 832d | 2014-12-30 | 2018-03-07 | 60 | 4658d | 0d |  |  | 21096h |  |
| 103 | 5.1 | **Production Licence (s62)** | 743d | 2014-12-30 | 2017-11-02 | 60 | 4747d |  |  |  | 5520h |  |
| 104 | 5.1.1 | Application Submitted | 1d | 2014-12-30 | 2014-12-30 | 60 | 5304d | 0d |  | Proponent | 8h |  |
| 105 | 5.1.2 | Assessment of application | 30d | 2014-12-31 | 2015-02-10 | 104 | 5429d | 0d |  | DMP PD | 240h |  |
| 106 | 5.1.3 | Final Field Development Plan and Schedule | 30d | 2015-02-11 | 2015-03-24 | 105 | 5429d |  |  | DMP PD | 240h |  |
| 107 | 5.1.4 | Determine and approve royalty regime | 30d | 2015-02-11 | 2015-03-24 | 105 | 5429d |  |  | DMP | 240h |  |
| 108 | 5.1.5 | **Native Title Agreements** | 185d | 2014-12-31 | 2015-09-15 |  | 5304d |  |  | DMP/NNTT | 4064h | http://www.dmp.wa.gov.au/487.aspx |
| 109 | 5.1.5.1 | Advertised (s29 NTA) | 120d | 2014-12-31 | 2015-06-16 | 104 | 5304d | 0d |  | DMP MTD | 960h | http://www.dmp.wa.gov.au/documents/StatePolicyFlowchart.pdf |
| 110 | 5.1.5.2 | Administration | 60d | 2015-06-24 | 2015-09-15 | 109, 111 | 5304d |  | start no earlier than 2010-09-17 | DMP/NNTT | 480h |  |
| 111 | 5.1.5.3 | "Right to Negotiate" | 125d | 2014-12-31 | 2015-06-23 | 109SS | 5304d | 0d |  | DMP/NNTT | 1000h |  |
| 112 | 5.1.5.4 | State Deed (s31) | 18d | 2015-06-24 | 2015-07-17 | 109, 111 | 5346d |  |  | DMP PD | 144h |  |

Notes:
- 87: (volume dependent)
- 90: notification to landholders
- 91: this is an estimate only - times will vary depending on nature of agreements, only need to be in place by construction
- 92: DMP policy position - condition that construction must begin within two years
- 95: may be referred under EPBC Act for Federal government assessment
- 97: estimate only
- 100: may be referred under EPBC Act for Federal government assessment
- 105: http://www.dmp.wa.gov.au/documents/EXPLORATION_PERMIT_APPLICATION_PROCESS_FLOWCHART_(WEB).pdf
- 106: estimate only, timelines depend on quality of preliminary field development proposal

| ID | WBS | Task | Duration | Start | Finish | Predecessors | Total slack | Free slack | Resources | Work |
| --- | --- | --- | --- | --- | --- | --- | --- | --- | --- | --- |
| 113 | 5.1.6 | **Grant Production Licence** | 91d | 2017-06-29 | 2017-11-02 | 151 | 4658d |  |  | 728h |
| 114 | 5.1.6.1 | Offer of grant | 30d | 2017-06-29 | 2017-08-09 | 151 | 4658d | 0d | DMP PD | 240h |
| 115 | 5.1.6.2 | Consideration of offer | 3mo | 2017-08-10 | 2017-11-01 | 114 | 4658d | 0d | Proponent | 480h |
| 116 | 5.1.6.3 | Award of Licence | 1d | 2017-11-02 | 2017-11-02 | 115 | 4747d |  | DMP PD | 8h |
| 117 | 5.2 | **Production Facility Approval** | 60d | 2017-06-29 | 2017-09-20 | 151 | 4778d |  | DMP PD | 1920h |
| 118 | 5.2.1 | **approval to construct** | 30d | 2017-06-29 | 2017-08-09 | 151 | 4778d | 0d |  | 960h |
| 119 | 5.2.1.1 | Safety Management Case | 30d | 2017-06-29 | 2017-08-09 |  | 4778d |  | DMP RSD | 240h |
| 120 | 5.2.1.2 | Environment Plans | 30d | 2017-06-29 | 2017-08-09 |  | 4778d |  | DMP ED | 240h |
| 121 | 5.2.1.3 | Native Vegetation Clearing Approvals (schedule 6) (EP Act) | 30d | 2017-06-29 | 2017-08-09 |  | 4778d |  | DMP ED | 240h |
| 122 | 5.2.1.4 | Heritage Clearance | 30d | 2017-06-29 | 2017-08-09 |  | 4778d |  | DIA | 240h |
| 123 | 5.2.2 | **Approval to operate (s36)** | 30d | 2017-08-10 | 2017-09-20 | 151 | 4778d |  |  | 480h |
| 124 | 5.2.2.1 | Safety Management Case | 30d | 2017-08-10 | 2017-09-20 | 118 | 4778d |  | DMP RSD | 240h |
| 125 | 5.2.2.2 | Environment Plans | 30d | 2017-08-10 | 2017-09-20 | 118 | 4778d |  | DMP PD | 240h |
| 126 | 5.3 | **State Environmental Assessment (Pt 4 EP Act)** | 643d | 2014-12-30 | 2017-06-15 |  | 4658d |  | OEPA | 9560h |
| 127 | 5.3.1 | EP Act Referral (s38 EP Act)/Public comment period | 7d | 2014-12-30 | 2015-01-07 |  | 4658d | 0d | Proponent | 56h |
| 128 | 5.3.2 | EPA consideration/Advice to proponent on whether to Assess and level of assessment | 28d | 2015-01-08 | 2015-02-16 | 127 | 4658d | 0d | OEPA | 224h |
| 129 | 5.3.3 | Proponent prepares ESD/EPA receives 1st draft ESD | 14d | 2015-02-17 | 2015-03-06 | 128 | 4658d | 0d | Proponent | 112h |
| 130 | 5.3.4 | OEPA comments on 1st draft ESD | 35d | 2015-03-09 | 2015-04-24 | 129 | 4658d | 0d | OEPA | 280h |
| 131 | 5.3.5 | Proponents prepares revised ESD | 21d | 2015-04-27 | 2015-05-25 | 130 | 4658d | 0d | Proponent | 168h |
| 132 | 5.3.6 | EPA authorises release of ESD for Public Review | 14d | 2015-05-26 | 2015-06-12 | 131 | 4658d | 0d | OEPA | 112h |
| 133 | 5.3.7 | ESD Public Review | 14d | 2015-06-15 | 2015-07-02 | 132 | 4658d | 0d |  |  |
| 134 | 5.3.8 | Summary of submissions provided to proponent | 14d | 2015-07-03 | 2015-07-22 | 133 | 4658d | 0d | OEPA | 112h |
| 135 | 5.3.9 | Proponent response to submissions and revision of ESD | 21d | 2015-07-23 | 2015-08-20 | 134 | 4658d | 0d | Proponent | 168h |
| 136 | 5.3.10 | ESD Approval | 35d | 2015-08-21 | 2015-10-08 | 135 | 4658d | 0d | OEPA | 280h |
| 137 | 5.3.11 | Proponent prepares draft ERMP/EPA receives 1st draft ERMP | 90d | 2015-10-09 | 2016-02-11 | 136 | 4658d | 0d | Proponent | 720h |
| 138 | 5.3.12 | OEPA provides comments on ERMP document | 42d | 2016-02-12 | 2016-04-11 | 137 | 4658d | 0d | OEPA | 336h |
| 139 | 5.3.13 | Proponent revised ERMP document | 42d | 2016-04-12 | 2016-06-08 | 138 | 4658d | 0d | Proponent | 336h |
| 140 | 5.3.14 | EPA authorises release of ERMP for public review | 14d | 2016-06-09 | 2016-06-28 | 139 | 4658d | 0d | OEPA | 112h |
| 141 | 5.3.15 | Public Review period for ERMP document | 70d | 2016-06-29 | 2016-10-04 | 140 | 4658d | 0d |  |  |
| 142 | 5.3.16 | OEPA provides summary of submissions to proponent | 21d | 2016-10-05 | 2016-11-02 | 141 | 4658d | 0d | OEPA | 168h |
| 143 | 5.3.17 | Proponent prepares submission summary and response | 42d | 2016-11-03 | 2016-12-30 | 142 | 4658d | 0d | Proponent | 336h |
| 144 | 5.3.18 | OEPA reviews response to submissions | 49d | 2017-01-02 | 2017-03-09 | 143 | 4658d | 0d | OEPA | 392h |
| 145 | 5.3.19 | EPA consults with proponent and key agencies on condistions | 14d | 2017-03-10 | 2017-03-29 | 144 | 4658d | 0d | OEPA | 112h |
| 146 | 5.3.20 | EPA report and recommendations prepared/EPA report published | 35d | 2017-03-30 | 2017-05-17 | 145 | 4658d | 0d | OEPA | 280h |
| 147 | 5.3.21 | Appeal period to the Minister on EPA report | 21d | 2017-05-18 | 2017-06-15 | 146 | 4847d |  |  |  |
| 148 | 5.3.22 | Minister considers EPA report/Minister makes decision | 14d | 2017-05-18 | 2017-06-06 | 146 | 4854d |  | OEPA | 112h |

Notes:
- 122: estimate only
- 126: NB. Projects may be referred from exploration through to development / Text1: http://edit.epa.wa.gov.au/EPADocLib/EAG%206Timelines%20for%20EIA%20of%20Proposals%20291110.pdf
- 127: Text1: http://www.dsd.wa.gov.au/documents/EPActPartIVReferralProcess.pdf
- 129: if EPA prepares ESD, allow 6 weeks for consultation with other agencies / Text1: http://www.epa.wa.gov.au/docs/1919_5%20eia%20scoping%20document%20guide_1-11-04.pdf
- 130: if EPA prepares ESD, this step is removed
- 137: this is a very conservative estimate. More likely 12 months / Text1: http://www.epa.wa.gov.au/docs/1921_7%20eia%20per-ermp%20guidelines_1-11-04.pdf
- 139: very conservative
- 141: can be up to 12 weeks

| ID | WBS | Task | Type | Duration | Start | Finish | Predecessors | Total slack | Free slack | Constraint | Resources | Work |
| --- | --- | --- | --- | --- | --- | --- | --- | --- | --- | --- | --- | --- |
| 149 | 5.4 | **Comonwealth EPBC Act Referrals** |  | 645d | 2015-01-08 | 2017-06-28 |  | 4658d |  |  |  |  |
| 150 | 5.4.1 | EPBC Act Referral |  | 20d | 2015-01-08 | 2015-02-04 | 127 | 5253d | 595d |  |  |  |
| 151 | 5.4.2 | Minister considers EPA report, 'sign off' |  | 30d | 2017-05-18 | 2017-06-28 | 150, 146 | 4658d | 0d |  |  |  |
| 152 | 5.5 | **State Works Approval & Licensing (Pt 5 EP Act)** |  | 60d | 2017-11-02 | 2018-01-24 |  | 4688d |  |  | DEC | 1768h |
| 153 | 5.5.1 | Advertised |  | 21d | 2017-11-02 | 2017-11-30 | 154SS | 4727d | 0d |  | DEC | 168h |
| 154 | 5.5.2 | Works (s52/53 EP Act) - Application/Assessment/Approval |  | 60d | 2017-11-02 | 2018-01-24 | 115 | 4688d | 0d |  | DEC | 480h |
| 155 | 5.5.3 | License to discharge etc (s56 EP Act) - Approval/Assessment/Licence Issued |  | 60d | 2017-11-02 | 2018-01-24 | 154SS | 4688d |  |  | DEC | 480h |
| 156 | 5.5.4 | Registration of Prescribed Premises (r5A EPR) - Application/Assessment/Approval |  | 20d | 2017-11-02 | 2017-11-29 | 153SS | 4728d |  |  | DEC | 160h |
| 157 | 5.6 | **Application for Production Well(s)** |  | 90d | 2017-11-01 | 2018-03-07 | 115 | 4658d |  |  |  | 2328h |
| 158 | 5.6.1 | Submit application | milestone | 0d | 2017-11-01 | 2017-11-01 | 115 | 4658d | 0d |  | Proponent |  |
| 159 | 5.6.2 | Assess Technical Report |  | 30d | 2017-11-02 | 2017-12-13 | 158SS | 4718d |  |  | DMP PD | 240h |
| 160 | 5.6.3 | Assess Well Operation Management Plan (WOMP) Drill Program, Well Intervention and Well Abandonment plan |  | 30d | 2017-11-02 | 2017-12-13 | 158SS | 4718d |  |  | DMP PD | 240h |
| 161 | 5.6.4 | Assess Safety Management System |  | 20d | 2017-11-02 | 2017-11-29 | 158SS | 4728d |  |  | DMP RSD | 160h |
| 162 | 5.6.5 | Heritage Clearance |  | 30d | 2017-11-02 | 2017-12-13 | 158SS | 4718d |  |  | DIA | 240h |
| 163 | 5.6.6 | Access and Compensation Agreements |  | 90d | 2017-11-02 | 2018-03-07 | 158SS | 4658d |  |  | Proponent | 720h |
| 164 | 5.6.7 | Environment Plans |  | 30ed | 2017-11-01 | 2017-12-01 | 158SS | 19855.9d | 288d |  | DMP ED | 720h |
| 165 | 5.6.8 | Data submission |  | 1d | 2017-11-02 | 2017-11-02 |  | 4747d |  |  | Proponent | 8h |
| 166 | 6 | **PRODUCTION ACTIVITY** |  | 4967d | 2018-03-07 | 2037-03-23 | 102 | 0d |  |  |  | 133696h |
| 167 | 6.1 | **Monthly Production Reports** |  | 4952d | 2018-03-08 | 2037-02-27 | 164 | 15d |  |  |  |  |
| 168 | 6.1.1 | Monthly Production Reports 1 |  | 1d | 2018-03-08 | 2018-03-08 |  | 4966d |  | start no earlier than 2012-02-27 |  |  |
| 169 | 6.1.2 | Monthly Production Reports 2 |  | 1d | 2018-03-08 | 2018-03-08 |  | 4966d |  | start no earlier than 2012-03-27 |  |  |
| 170 | 6.1.3 | Monthly Production Reports 3 |  | 1d | 2018-03-08 | 2018-03-08 |  | 4966d |  | start no earlier than 2012-04-27 |  |  |
| 171 | 6.1.4 | Monthly Production Reports 4 |  | 1d | 2018-03-08 | 2018-03-08 |  | 4966d |  | start no earlier than 2012-05-27 |  |  |
| 172 | 6.1.5 | Monthly Production Reports 5 |  | 1d | 2018-03-08 | 2018-03-08 |  | 4966d |  | start no earlier than 2012-06-27 |  |  |
| 173 | 6.1.6 | Monthly Production Reports 6 |  | 1d | 2018-03-08 | 2018-03-08 |  | 4966d |  | start no earlier than 2012-07-27 |  |  |
| 174 | 6.1.7 | Monthly Production Reports 7 |  | 1d | 2018-03-08 | 2018-03-08 |  | 4966d |  | start no earlier than 2012-08-27 |  |  |
| 175 | 6.1.8 | Monthly Production Reports 8 |  | 1d | 2018-03-08 | 2018-03-08 |  | 4966d |  | start no earlier than 2012-09-27 |  |  |
| 176 | 6.1.9 | Monthly Production Reports 9 |  | 1d | 2018-03-08 | 2018-03-08 |  | 4966d |  | start no earlier than 2012-10-27 |  |  |
| 177 | 6.1.10 | Monthly Production Reports 10 |  | 1d | 2018-03-08 | 2018-03-08 |  | 4966d |  | start no earlier than 2012-11-27 |  |  |
| 178 | 6.1.11 | Monthly Production Reports 11 |  | 1d | 2018-03-08 | 2018-03-08 |  | 4966d |  | start no earlier than 2012-12-27 |  |  |
| 179 | 6.1.12 | Monthly Production Reports 12 |  | 1d | 2018-03-08 | 2018-03-08 |  | 4966d |  | start no earlier than 2013-01-27 |  |  |
| 180 | 6.1.13 | Monthly Production Reports 13 |  | 1d | 2018-03-08 | 2018-03-08 |  | 4966d |  | start no earlier than 2013-02-27 |  |  |
| 181 | 6.1.14 | Monthly Production Reports 14 |  | 1d | 2018-03-08 | 2018-03-08 |  | 4966d |  | start no earlier than 2013-03-27 |  |  |
| 182 | 6.1.15 | Monthly Production Reports 15 |  | 1d | 2018-03-08 | 2018-03-08 |  | 4966d |  | start no earlier than 2013-04-27 |  |  |
| 183 | 6.1.16 | Monthly Production Reports 16 |  | 1d | 2018-03-08 | 2018-03-08 |  | 4966d |  | start no earlier than 2013-05-27 |  |  |
| 184 | 6.1.17 | Monthly Production Reports 17 |  | 1d | 2018-03-08 | 2018-03-08 |  | 4966d |  | start no earlier than 2013-06-27 |  |  |
| 185 | 6.1.18 | Monthly Production Reports 18 |  | 1d | 2018-03-08 | 2018-03-08 |  | 4966d |  | start no earlier than 2013-07-27 |  |  |
| 186 | 6.1.19 | Monthly Production Reports 19 |  | 1d | 2018-03-08 | 2018-03-08 |  | 4966d |  | start no earlier than 2013-08-27 |  |  |
| 187 | 6.1.20 | Monthly Production Reports 20 |  | 1d | 2018-03-08 | 2018-03-08 |  | 4966d |  | start no earlier than 2013-09-27 |  |  |
| 188 | 6.1.21 | Monthly Production Reports 21 |  | 1d | 2018-03-08 | 2018-03-08 |  | 4966d |  | start no earlier than 2013-10-27 |  |  |
| 189 | 6.1.22 | Monthly Production Reports 22 |  | 1d | 2018-03-08 | 2018-03-08 |  | 4966d |  | start no earlier than 2013-11-27 |  |  |
| 190 | 6.1.23 | Monthly Production Reports 23 |  | 1d | 2018-03-08 | 2018-03-08 |  | 4966d |  | start no earlier than 2013-12-27 |  |  |
| 191 | 6.1.24 | Monthly Production Reports 24 |  | 1d | 2018-03-08 | 2018-03-08 |  | 4966d |  | start no earlier than 2014-01-27 |  |  |
| 192 | 6.1.25 | Monthly Production Reports 25 |  | 1d | 2018-03-08 | 2018-03-08 |  | 4966d |  | start no earlier than 2014-02-27 |  |  |
| 193 | 6.1.26 | Monthly Production Reports 26 |  | 1d | 2018-03-08 | 2018-03-08 |  | 4966d |  | start no earlier than 2014-03-27 |  |  |
| 194 | 6.1.27 | Monthly Production Reports 27 |  | 1d | 2018-03-08 | 2018-03-08 |  | 4966d |  | start no earlier than 2014-04-27 |  |  |
| 195 | 6.1.28 | Monthly Production Reports 28 |  | 1d | 2018-03-08 | 2018-03-08 |  | 4966d |  | start no earlier than 2014-05-27 |  |  |
| 196 | 6.1.29 | Monthly Production Reports 29 |  | 1d | 2018-03-08 | 2018-03-08 |  | 4966d |  | start no earlier than 2014-06-27 |  |  |
| 197 | 6.1.30 | Monthly Production Reports 30 |  | 1d | 2018-03-08 | 2018-03-08 |  | 4966d |  | start no earlier than 2014-07-27 |  |  |
| 198 | 6.1.31 | Monthly Production Reports 31 |  | 1d | 2018-03-08 | 2018-03-08 |  | 4966d |  | start no earlier than 2014-08-27 |  |  |
| 199 | 6.1.32 | Monthly Production Reports 32 |  | 1d | 2018-03-08 | 2018-03-08 |  | 4966d |  | start no earlier than 2014-09-27 |  |  |
| 200 | 6.1.33 | Monthly Production Reports 33 |  | 1d | 2018-03-08 | 2018-03-08 |  | 4966d |  | start no earlier than 2014-10-27 |  |  |
| 201 | 6.1.34 | Monthly Production Reports 34 |  | 1d | 2018-03-08 | 2018-03-08 |  | 4966d |  | start no earlier than 2014-11-27 |  |  |
| 202 | 6.1.35 | Monthly Production Reports 35 |  | 1d | 2018-03-08 | 2018-03-08 |  | 4966d |  | start no earlier than 2014-12-27 |  |  |
| 203 | 6.1.36 | Monthly Production Reports 36 |  | 1d | 2018-03-08 | 2018-03-08 |  | 4966d |  | start no earlier than 2015-01-27 |  |  |
| 204 | 6.1.37 | Monthly Production Reports 37 |  | 1d | 2018-03-08 | 2018-03-08 |  | 4966d |  | start no earlier than 2015-02-27 |  |  |
| 205 | 6.1.38 | Monthly Production Reports 38 |  | 1d | 2018-03-08 | 2018-03-08 |  | 4966d |  | start no earlier than 2015-03-27 |  |  |
| 206 | 6.1.39 | Monthly Production Reports 39 |  | 1d | 2018-03-08 | 2018-03-08 |  | 4966d |  | start no earlier than 2015-04-27 |  |  |
| 207 | 6.1.40 | Monthly Production Reports 40 |  | 1d | 2018-03-08 | 2018-03-08 |  | 4966d |  | start no earlier than 2015-05-27 |  |  |
| 208 | 6.1.41 | Monthly Production Reports 41 |  | 1d | 2018-03-08 | 2018-03-08 |  | 4966d |  | start no earlier than 2015-06-27 |  |  |
| 209 | 6.1.42 | Monthly Production Reports 42 |  | 1d | 2018-03-08 | 2018-03-08 |  | 4966d |  | start no earlier than 2015-07-27 |  |  |
| 210 | 6.1.43 | Monthly Production Reports 43 |  | 1d | 2018-03-08 | 2018-03-08 |  | 4966d |  | start no earlier than 2015-08-27 |  |  |
| 211 | 6.1.44 | Monthly Production Reports 44 |  | 1d | 2018-03-08 | 2018-03-08 |  | 4966d |  | start no earlier than 2015-09-27 |  |  |
| 212 | 6.1.45 | Monthly Production Reports 45 |  | 1d | 2018-03-08 | 2018-03-08 |  | 4966d |  | start no earlier than 2015-10-27 |  |  |
| 213 | 6.1.46 | Monthly Production Reports 46 |  | 1d | 2018-03-08 | 2018-03-08 |  | 4966d |  | start no earlier than 2015-11-27 |  |  |
| 214 | 6.1.47 | Monthly Production Reports 47 |  | 1d | 2018-03-08 | 2018-03-08 |  | 4966d |  | start no earlier than 2015-12-27 |  |  |
| 215 | 6.1.48 | Monthly Production Reports 48 |  | 1d | 2018-03-08 | 2018-03-08 |  | 4966d |  | start no earlier than 2016-01-27 |  |  |
| 216 | 6.1.49 | Monthly Production Reports 49 |  | 1d | 2018-03-08 | 2018-03-08 |  | 4966d |  | start no earlier than 2016-02-27 |  |  |
| 217 | 6.1.50 | Monthly Production Reports 50 |  | 1d | 2018-03-08 | 2018-03-08 |  | 4966d |  | start no earlier than 2016-03-27 |  |  |
| 218 | 6.1.51 | Monthly Production Reports 51 |  | 1d | 2018-03-08 | 2018-03-08 |  | 4966d |  | start no earlier than 2016-04-27 |  |  |

Notes:
- 149: NB. Projects may be referred from exploration through to development
- 152: Text1: http://www.dec.wa.gov.au/index.php?option=com_content&Itemid=1557&id=3512&lang=en&task=view
- 153: DEC reuires proponents to undertake scoping meeting
- 157: batch approvals may be sought. During life of field approvals are required for any new well & well intervention
- 163: this is an estimate only - times will vary depending on nature of agreements
- 165: proponent must submit resource data to DMP throughout activity
- 166: this is just an estimate, some wells may go for as long as 40 years

| ID | WBS | Task | Duration | Start | Finish | Total slack | Constraint |
| --- | --- | --- | --- | --- | --- | --- | --- |
| 219 | 6.1.52 | Monthly Production Reports 52 | 1d | 2018-03-08 | 2018-03-08 | 4966d | start no earlier than 2016-05-27 |
| 220 | 6.1.53 | Monthly Production Reports 53 | 1d | 2018-03-08 | 2018-03-08 | 4966d | start no earlier than 2016-06-27 |
| 221 | 6.1.54 | Monthly Production Reports 54 | 1d | 2018-03-08 | 2018-03-08 | 4966d | start no earlier than 2016-07-27 |
| 222 | 6.1.55 | Monthly Production Reports 55 | 1d | 2018-03-08 | 2018-03-08 | 4966d | start no earlier than 2016-08-27 |
| 223 | 6.1.56 | Monthly Production Reports 56 | 1d | 2018-03-08 | 2018-03-08 | 4966d | start no earlier than 2016-09-27 |
| 224 | 6.1.57 | Monthly Production Reports 57 | 1d | 2018-03-08 | 2018-03-08 | 4966d | start no earlier than 2016-10-27 |
| 225 | 6.1.58 | Monthly Production Reports 58 | 1d | 2018-03-08 | 2018-03-08 | 4966d | start no earlier than 2016-11-27 |
| 226 | 6.1.59 | Monthly Production Reports 59 | 1d | 2018-03-08 | 2018-03-08 | 4966d | start no earlier than 2016-12-27 |
| 227 | 6.1.60 | Monthly Production Reports 60 | 1d | 2018-03-08 | 2018-03-08 | 4966d | start no earlier than 2017-01-27 |
| 228 | 6.1.61 | Monthly Production Reports 61 | 1d | 2018-03-08 | 2018-03-08 | 4966d | start no earlier than 2017-02-27 |
| 229 | 6.1.62 | Monthly Production Reports 62 | 1d | 2018-03-08 | 2018-03-08 | 4966d | start no earlier than 2017-03-27 |
| 230 | 6.1.63 | Monthly Production Reports 63 | 1d | 2018-03-08 | 2018-03-08 | 4966d | start no earlier than 2017-04-27 |
| 231 | 6.1.64 | Monthly Production Reports 64 | 1d | 2018-03-08 | 2018-03-08 | 4966d | start no earlier than 2017-05-27 |
| 232 | 6.1.65 | Monthly Production Reports 65 | 1d | 2018-03-08 | 2018-03-08 | 4966d | start no earlier than 2017-06-27 |
| 233 | 6.1.66 | Monthly Production Reports 66 | 1d | 2018-03-08 | 2018-03-08 | 4966d | start no earlier than 2017-07-27 |
| 234 | 6.1.67 | Monthly Production Reports 67 | 1d | 2018-03-08 | 2018-03-08 | 4966d | start no earlier than 2017-08-27 |
| 235 | 6.1.68 | Monthly Production Reports 68 | 1d | 2018-03-08 | 2018-03-08 | 4966d | start no earlier than 2017-09-27 |
| 236 | 6.1.69 | Monthly Production Reports 69 | 1d | 2018-03-08 | 2018-03-08 | 4966d | start no earlier than 2017-10-27 |
| 237 | 6.1.70 | Monthly Production Reports 70 | 1d | 2018-03-08 | 2018-03-08 | 4966d | start no earlier than 2017-11-27 |
| 238 | 6.1.71 | Monthly Production Reports 71 | 1d | 2018-03-08 | 2018-03-08 | 4966d | start no earlier than 2017-12-27 |
| 239 | 6.1.72 | Monthly Production Reports 72 | 1d | 2018-03-08 | 2018-03-08 | 4966d | start no earlier than 2018-01-27 |
| 240 | 6.1.73 | Monthly Production Reports 73 | 1d | 2018-03-08 | 2018-03-08 | 4966d | start no earlier than 2018-02-27 |
| 241 | 6.1.74 | Monthly Production Reports 74 | 1d | 2018-03-27 | 2018-03-27 | 4953d | start no earlier than 2018-03-27 |
| 242 | 6.1.75 | Monthly Production Reports 75 | 1d | 2018-04-27 | 2018-04-27 | 4930d | start no earlier than 2018-04-27 |
| 243 | 6.1.76 | Monthly Production Reports 76 | 1d | 2018-05-28 | 2018-05-28 | 4909d | start no earlier than 2018-05-27 |
| 244 | 6.1.77 | Monthly Production Reports 77 | 1d | 2018-06-27 | 2018-06-27 | 4887d | start no earlier than 2018-06-27 |
| 245 | 6.1.78 | Monthly Production Reports 78 | 1d | 2018-07-27 | 2018-07-27 | 4865d | start no earlier than 2018-07-27 |
| 246 | 6.1.79 | Monthly Production Reports 79 | 1d | 2018-08-27 | 2018-08-27 | 4844d | start no earlier than 2018-08-27 |
| 247 | 6.1.80 | Monthly Production Reports 80 | 1d | 2018-09-27 | 2018-09-27 | 4821d | start no earlier than 2018-09-27 |
| 248 | 6.1.81 | Monthly Production Reports 81 | 1d | 2018-10-29 | 2018-10-29 | 4799d | start no earlier than 2018-10-27 |
| 249 | 6.1.82 | Monthly Production Reports 82 | 1d | 2018-11-27 | 2018-11-27 | 4778d | start no earlier than 2018-11-27 |
| 250 | 6.1.83 | Monthly Production Reports 83 | 1d | 2018-12-27 | 2018-12-27 | 4756d | start no earlier than 2018-12-27 |
| 251 | 6.1.84 | Monthly Production Reports 84 | 1d | 2019-01-28 | 2019-01-28 | 4734d | start no earlier than 2019-01-27 |
| 252 | 6.1.85 | Monthly Production Reports 85 | 1d | 2019-02-27 | 2019-02-27 | 4712d | start no earlier than 2019-02-27 |
| 253 | 6.1.86 | Monthly Production Reports 86 | 1d | 2019-03-27 | 2019-03-27 | 4692d | start no earlier than 2019-03-27 |
| 254 | 6.1.87 | Monthly Production Reports 87 | 1d | 2019-04-29 | 2019-04-29 | 4669d | start no earlier than 2019-04-27 |
| 255 | 6.1.88 | Monthly Production Reports 88 | 1d | 2019-05-27 | 2019-05-27 | 4649d | start no earlier than 2019-05-27 |
| 256 | 6.1.89 | Monthly Production Reports 89 | 1d | 2019-06-27 | 2019-06-27 | 4626d | start no earlier than 2019-06-27 |
| 257 | 6.1.90 | Monthly Production Reports 90 | 1d | 2019-07-29 | 2019-07-29 | 4604d | start no earlier than 2019-07-27 |
| 258 | 6.1.91 | Monthly Production Reports 91 | 1d | 2019-08-27 | 2019-08-27 | 4583d | start no earlier than 2019-08-27 |
| 259 | 6.1.92 | Monthly Production Reports 92 | 1d | 2019-09-27 | 2019-09-27 | 4560d | start no earlier than 2019-09-27 |
| 260 | 6.1.93 | Monthly Production Reports 93 | 1d | 2019-10-28 | 2019-10-28 | 4539d | start no earlier than 2019-10-27 |
| 261 | 6.1.94 | Monthly Production Reports 94 | 1d | 2019-11-27 | 2019-11-27 | 4517d | start no earlier than 2019-11-27 |
| 262 | 6.1.95 | Monthly Production Reports 95 | 1d | 2019-12-27 | 2019-12-27 | 4495d | start no earlier than 2019-12-27 |
| 263 | 6.1.96 | Monthly Production Reports 96 | 1d | 2020-01-27 | 2020-01-27 | 4474d | start no earlier than 2020-01-27 |
| 264 | 6.1.97 | Monthly Production Reports 97 | 1d | 2020-02-27 | 2020-02-27 | 4451d | start no earlier than 2020-02-27 |
| 265 | 6.1.98 | Monthly Production Reports 98 | 1d | 2020-03-27 | 2020-03-27 | 4430d | start no earlier than 2020-03-27 |
| 266 | 6.1.99 | Monthly Production Reports 99 | 1d | 2020-04-27 | 2020-04-27 | 4409d | start no earlier than 2020-04-27 |
| 267 | 6.1.100 | Monthly Production Reports 100 | 1d | 2020-05-27 | 2020-05-27 | 4387d | start no earlier than 2020-05-27 |
| 268 | 6.1.101 | Monthly Production Reports 101 | 1d | 2020-06-29 | 2020-06-29 | 4364d | start no earlier than 2020-06-27 |
| 269 | 6.1.102 | Monthly Production Reports 102 | 1d | 2020-07-27 | 2020-07-27 | 4344d | start no earlier than 2020-07-27 |
| 270 | 6.1.103 | Monthly Production Reports 103 | 1d | 2020-08-27 | 2020-08-27 | 4321d | start no earlier than 2020-08-27 |
| 271 | 6.1.104 | Monthly Production Reports 104 | 1d | 2020-09-28 | 2020-09-28 | 4299d | start no earlier than 2020-09-27 |
| 272 | 6.1.105 | Monthly Production Reports 105 | 1d | 2020-10-27 | 2020-10-27 | 4278d | start no earlier than 2020-10-27 |
| 273 | 6.1.106 | Monthly Production Reports 106 | 1d | 2020-11-27 | 2020-11-27 | 4255d | start no earlier than 2020-11-27 |
| 274 | 6.1.107 | Monthly Production Reports 107 | 1d | 2020-12-28 | 2020-12-28 | 4234d | start no earlier than 2020-12-27 |
| 275 | 6.1.108 | Monthly Production Reports 108 | 1d | 2021-01-27 | 2021-01-27 | 4212d | start no earlier than 2021-01-27 |
| 276 | 6.1.109 | Monthly Production Reports 109 | 1d | 2021-03-01 | 2021-03-01 | 4189d | start no earlier than 2021-02-27 |
| 277 | 6.1.110 | Monthly Production Reports 110 | 1d | 2021-03-29 | 2021-03-29 | 4169d | start no earlier than 2021-03-27 |
| 278 | 6.1.111 | Monthly Production Reports 111 | 1d | 2021-04-27 | 2021-04-27 | 4148d | start no earlier than 2021-04-27 |
| 279 | 6.1.112 | Monthly Production Reports 112 | 1d | 2021-05-27 | 2021-05-27 | 4126d | start no earlier than 2021-05-27 |
| 280 | 6.1.113 | Monthly Production Reports 113 | 1d | 2021-06-28 | 2021-06-28 | 4104d | start no earlier than 2021-06-27 |
| 281 | 6.1.114 | Monthly Production Reports 114 | 1d | 2021-07-27 | 2021-07-27 | 4083d | start no earlier than 2021-07-27 |
| 282 | 6.1.115 | Monthly Production Reports 115 | 1d | 2021-08-27 | 2021-08-27 | 4060d | start no earlier than 2021-08-27 |
| 283 | 6.1.116 | Monthly Production Reports 116 | 1d | 2021-09-27 | 2021-09-27 | 4039d | start no earlier than 2021-09-27 |
| 284 | 6.1.117 | Monthly Production Reports 117 | 1d | 2021-10-27 | 2021-10-27 | 4017d | start no earlier than 2021-10-27 |
| 285 | 6.1.118 | Monthly Production Reports 118 | 1d | 2021-11-29 | 2021-11-29 | 3994d | start no earlier than 2021-11-27 |
| 286 | 6.1.119 | Monthly Production Reports 119 | 1d | 2021-12-27 | 2021-12-27 | 3974d | start no earlier than 2021-12-27 |
| 287 | 6.1.120 | Monthly Production Reports 120 | 1d | 2022-01-27 | 2022-01-27 | 3951d | start no earlier than 2022-01-27 |
| 288 | 6.1.121 | Monthly Production Reports 121 | 1d | 2022-02-28 | 2022-02-28 | 3929d | start no earlier than 2022-02-27 |

| ID | WBS | Task | Duration | Start | Finish | Total slack | Constraint |
| --- | --- | --- | --- | --- | --- | --- | --- |
| 289 | 6.1.122 | Monthly Production Reports 122 | 1d | 2022-03-28 | 2022-03-28 | 3909d | start no earlier than 2022-03-27 |
| 290 | 6.1.123 | Monthly Production Reports 123 | 1d | 2022-04-27 | 2022-04-27 | 3887d | start no earlier than 2022-04-27 |
| 291 | 6.1.124 | Monthly Production Reports 124 | 1d | 2022-05-27 | 2022-05-27 | 3865d | start no earlier than 2022-05-27 |
| 292 | 6.1.125 | Monthly Production Reports 125 | 1d | 2022-06-27 | 2022-06-27 | 3844d | start no earlier than 2022-06-27 |
| 293 | 6.1.126 | Monthly Production Reports 126 | 1d | 2022-07-27 | 2022-07-27 | 3822d | start no earlier than 2022-07-27 |
| 294 | 6.1.127 | Monthly Production Reports 127 | 1d | 2022-08-29 | 2022-08-29 | 3799d | start no earlier than 2022-08-27 |
| 295 | 6.1.128 | Monthly Production Reports 128 | 1d | 2022-09-27 | 2022-09-27 | 3778d | start no earlier than 2022-09-27 |
| 296 | 6.1.129 | Monthly Production Reports 129 | 1d | 2022-10-27 | 2022-10-27 | 3756d | start no earlier than 2022-10-27 |
| 297 | 6.1.130 | Monthly Production Reports 130 | 1d | 2022-11-28 | 2022-11-28 | 3734d | start no earlier than 2022-11-27 |
| 298 | 6.1.131 | Monthly Production Reports 131 | 1d | 2022-12-27 | 2022-12-27 | 3713d | start no earlier than 2022-12-27 |
| 299 | 6.1.132 | Monthly Production Reports 132 | 1d | 2023-01-27 | 2023-01-27 | 3690d | start no earlier than 2023-01-27 |
| 300 | 6.1.133 | Monthly Production Reports 133 | 1d | 2023-02-27 | 2023-02-27 | 3669d | start no earlier than 2023-02-27 |
| 301 | 6.1.134 | Monthly Production Reports 134 | 1d | 2023-03-27 | 2023-03-27 | 3649d | start no earlier than 2023-03-27 |
| 302 | 6.1.135 | Monthly Production Reports 135 | 1d | 2023-04-27 | 2023-04-27 | 3626d | start no earlier than 2023-04-27 |
| 303 | 6.1.136 | Monthly Production Reports 136 | 1d | 2023-05-29 | 2023-05-29 | 3604d | start no earlier than 2023-05-27 |
| 304 | 6.1.137 | Monthly Production Reports 137 | 1d | 2023-06-27 | 2023-06-27 | 3583d | start no earlier than 2023-06-27 |
| 305 | 6.1.138 | Monthly Production Reports 138 | 1d | 2023-07-27 | 2023-07-27 | 3561d | start no earlier than 2023-07-27 |
| 306 | 6.1.139 | Monthly Production Reports 139 | 1d | 2023-08-28 | 2023-08-28 | 3539d | start no earlier than 2023-08-27 |
| 307 | 6.1.140 | Monthly Production Reports 140 | 1d | 2023-09-27 | 2023-09-27 | 3517d | start no earlier than 2023-09-27 |
| 308 | 6.1.141 | Monthly Production Reports 141 | 1d | 2023-10-27 | 2023-10-27 | 3495d | start no earlier than 2023-10-27 |
| 309 | 6.1.142 | Monthly Production Reports 142 | 1d | 2023-11-27 | 2023-11-27 | 3474d | start no earlier than 2023-11-27 |
| 310 | 6.1.143 | Monthly Production Reports 143 | 1d | 2023-12-27 | 2023-12-27 | 3452d | start no earlier than 2023-12-27 |
| 311 | 6.1.144 | Monthly Production Reports 144 | 1d | 2024-01-29 | 2024-01-29 | 3429d | start no earlier than 2024-01-27 |
| 312 | 6.1.145 | Monthly Production Reports 145 | 1d | 2024-02-27 | 2024-02-27 | 3408d | start no earlier than 2024-02-27 |
| 313 | 6.1.146 | Monthly Production Reports 146 | 1d | 2024-03-27 | 2024-03-27 | 3387d | start no earlier than 2024-03-27 |
| 314 | 6.1.147 | Monthly Production Reports 147 | 1d | 2024-04-29 | 2024-04-29 | 3364d | start no earlier than 2024-04-27 |
| 315 | 6.1.148 | Monthly Production Reports 148 | 1d | 2024-05-27 | 2024-05-27 | 3344d | start no earlier than 2024-05-27 |
| 316 | 6.1.149 | Monthly Production Reports 149 | 1d | 2024-06-27 | 2024-06-27 | 3321d | start no earlier than 2024-06-27 |
| 317 | 6.1.150 | Monthly Production Reports 150 | 1d | 2024-07-29 | 2024-07-29 | 3299d | start no earlier than 2024-07-27 |
| 318 | 6.1.151 | Monthly Production Reports 151 | 1d | 2024-08-27 | 2024-08-27 | 3278d | start no earlier than 2024-08-27 |
| 319 | 6.1.152 | Monthly Production Reports 152 | 1d | 2024-09-27 | 2024-09-27 | 3255d | start no earlier than 2024-09-27 |
| 320 | 6.1.153 | Monthly Production Reports 153 | 1d | 2024-10-28 | 2024-10-28 | 3234d | start no earlier than 2024-10-27 |
| 321 | 6.1.154 | Monthly Production Reports 154 | 1d | 2024-11-27 | 2024-11-27 | 3212d | start no earlier than 2024-11-27 |
| 322 | 6.1.155 | Monthly Production Reports 155 | 1d | 2024-12-27 | 2024-12-27 | 3190d | start no earlier than 2024-12-27 |
| 323 | 6.1.156 | Monthly Production Reports 156 | 1d | 2025-01-27 | 2025-01-27 | 3169d | start no earlier than 2025-01-27 |
| 324 | 6.1.157 | Monthly Production Reports 157 | 1d | 2025-02-27 | 2025-02-27 | 3146d | start no earlier than 2025-02-27 |
| 325 | 6.1.158 | Monthly Production Reports 158 | 1d | 2025-03-27 | 2025-03-27 | 3126d | start no earlier than 2025-03-27 |
| 326 | 6.1.159 | Monthly Production Reports 159 | 1d | 2025-04-28 | 2025-04-28 | 3104d | start no earlier than 2025-04-27 |
| 327 | 6.1.160 | Monthly Production Reports 160 | 1d | 2025-05-27 | 2025-05-27 | 3083d | start no earlier than 2025-05-27 |
| 328 | 6.1.161 | Monthly Production Reports 161 | 1d | 2025-06-27 | 2025-06-27 | 3060d | start no earlier than 2025-06-27 |
| 329 | 6.1.162 | Monthly Production Reports 162 | 1d | 2025-07-28 | 2025-07-28 | 3039d | start no earlier than 2025-07-27 |
| 330 | 6.1.163 | Monthly Production Reports 163 | 1d | 2025-08-27 | 2025-08-27 | 3017d | start no earlier than 2025-08-27 |
| 331 | 6.1.164 | Monthly Production Reports 164 | 1d | 2025-09-29 | 2025-09-29 | 2994d | start no earlier than 2025-09-27 |
| 332 | 6.1.165 | Monthly Production Reports 165 | 1d | 2025-10-27 | 2025-10-27 | 2974d | start no earlier than 2025-10-27 |
| 333 | 6.1.166 | Monthly Production Reports 166 | 1d | 2025-11-27 | 2025-11-27 | 2951d | start no earlier than 2025-11-27 |
| 334 | 6.1.167 | Monthly Production Reports 167 | 1d | 2025-12-29 | 2025-12-29 | 2929d | start no earlier than 2025-12-27 |
| 335 | 6.1.168 | Monthly Production Reports 168 | 1d | 2026-01-27 | 2026-01-27 | 2908d | start no earlier than 2026-01-27 |
| 336 | 6.1.169 | Monthly Production Reports 169 | 1d | 2026-02-27 | 2026-02-27 | 2885d | start no earlier than 2026-02-27 |
| 337 | 6.1.170 | Monthly Production Reports 170 | 1d | 2026-03-27 | 2026-03-27 | 2865d | start no earlier than 2026-03-27 |
| 338 | 6.1.171 | Monthly Production Reports 171 | 1d | 2026-04-27 | 2026-04-27 | 2844d | start no earlier than 2026-04-27 |
| 339 | 6.1.172 | Monthly Production Reports 172 | 1d | 2026-05-27 | 2026-05-27 | 2822d | start no earlier than 2026-05-27 |
| 340 | 6.1.173 | Monthly Production Reports 173 | 1d | 2026-06-29 | 2026-06-29 | 2799d | start no earlier than 2026-06-27 |
| 341 | 6.1.174 | Monthly Production Reports 174 | 1d | 2026-07-27 | 2026-07-27 | 2779d | start no earlier than 2026-07-27 |
| 342 | 6.1.175 | Monthly Production Reports 175 | 1d | 2026-08-27 | 2026-08-27 | 2756d | start no earlier than 2026-08-27 |
| 343 | 6.1.176 | Monthly Production Reports 176 | 1d | 2026-09-28 | 2026-09-28 | 2734d | start no earlier than 2026-09-27 |
| 344 | 6.1.177 | Monthly Production Reports 177 | 1d | 2026-10-27 | 2026-10-27 | 2713d | start no earlier than 2026-10-27 |
| 345 | 6.1.178 | Monthly Production Reports 178 | 1d | 2026-11-27 | 2026-11-27 | 2690d | start no earlier than 2026-11-27 |
| 346 | 6.1.179 | Monthly Production Reports 179 | 1d | 2026-12-28 | 2026-12-28 | 2669d | start no earlier than 2026-12-27 |
| 347 | 6.1.180 | Monthly Production Reports 180 | 1d | 2027-01-27 | 2027-01-27 | 2647d | start no earlier than 2027-01-27 |
| 348 | 6.1.181 | Monthly Production Reports 181 | 1d | 2027-03-01 | 2027-03-01 | 2624d | start no earlier than 2027-02-27 |
| 349 | 6.1.182 | Monthly Production Reports 182 | 1d | 2027-03-29 | 2027-03-29 | 2604d | start no earlier than 2027-03-27 |
| 350 | 6.1.183 | Monthly Production Reports 183 | 1d | 2027-04-27 | 2027-04-27 | 2583d | start no earlier than 2027-04-27 |
| 351 | 6.1.184 | Monthly Production Reports 184 | 1d | 2027-05-27 | 2027-05-27 | 2561d | start no earlier than 2027-05-27 |
| 352 | 6.1.185 | Monthly Production Reports 185 | 1d | 2027-06-28 | 2027-06-28 | 2539d | start no earlier than 2027-06-27 |
| 353 | 6.1.186 | Monthly Production Reports 186 | 1d | 2027-07-27 | 2027-07-27 | 2518d | start no earlier than 2027-07-27 |
| 354 | 6.1.187 | Monthly Production Reports 187 | 1d | 2027-08-27 | 2027-08-27 | 2495d | start no earlier than 2027-08-27 |
| 355 | 6.1.188 | Monthly Production Reports 188 | 1d | 2027-09-27 | 2027-09-27 | 2474d | start no earlier than 2027-09-27 |
| 356 | 6.1.189 | Monthly Production Reports 189 | 1d | 2027-10-27 | 2027-10-27 | 2452d | start no earlier than 2027-10-27 |
| 357 | 6.1.190 | Monthly Production Reports 190 | 1d | 2027-11-29 | 2027-11-29 | 2429d | start no earlier than 2027-11-27 |
| 358 | 6.1.191 | Monthly Production Reports 191 | 1d | 2027-12-27 | 2027-12-27 | 2409d | start no earlier than 2027-12-27 |

| ID | WBS | Task | Duration | Start | Finish | Total slack | Constraint |
| --- | --- | --- | --- | --- | --- | --- | --- |
| 359 | 6.1.192 | Monthly Production Reports 192 | 1d | 2028-01-27 | 2028-01-27 | 2386d | start no earlier than 2028-01-27 |
| 360 | 6.1.193 | Monthly Production Reports 193 | 1d | 2028-02-28 | 2028-02-28 | 2364d | start no earlier than 2028-02-27 |
| 361 | 6.1.194 | Monthly Production Reports 194 | 1d | 2028-03-27 | 2028-03-27 | 2344d | start no earlier than 2028-03-27 |
| 362 | 6.1.195 | Monthly Production Reports 195 | 1d | 2028-04-27 | 2028-04-27 | 2321d | start no earlier than 2028-04-27 |
| 363 | 6.1.196 | Monthly Production Reports 196 | 1d | 2028-05-29 | 2028-05-29 | 2299d | start no earlier than 2028-05-27 |
| 364 | 6.1.197 | Monthly Production Reports 197 | 1d | 2028-06-27 | 2028-06-27 | 2278d | start no earlier than 2028-06-27 |
| 365 | 6.1.198 | Monthly Production Reports 198 | 1d | 2028-07-27 | 2028-07-27 | 2256d | start no earlier than 2028-07-27 |
| 366 | 6.1.199 | Monthly Production Reports 199 | 1d | 2028-08-28 | 2028-08-28 | 2234d | start no earlier than 2028-08-27 |
| 367 | 6.1.200 | Monthly Production Reports 200 | 1d | 2028-09-27 | 2028-09-27 | 2212d | start no earlier than 2028-09-27 |
| 368 | 6.1.201 | Monthly Production Reports 201 | 1d | 2028-10-27 | 2028-10-27 | 2190d | start no earlier than 2028-10-27 |
| 369 | 6.1.202 | Monthly Production Reports 202 | 1d | 2028-11-27 | 2028-11-27 | 2169d | start no earlier than 2028-11-27 |
| 370 | 6.1.203 | Monthly Production Reports 203 | 1d | 2028-12-27 | 2028-12-27 | 2147d | start no earlier than 2028-12-27 |
| 371 | 6.1.204 | Monthly Production Reports 204 | 1d | 2029-01-29 | 2029-01-29 | 2124d | start no earlier than 2029-01-27 |
| 372 | 6.1.205 | Monthly Production Reports 205 | 1d | 2029-02-27 | 2029-02-27 | 2103d | start no earlier than 2029-02-27 |
| 373 | 6.1.206 | Monthly Production Reports 206 | 1d | 2029-03-27 | 2029-03-27 | 2083d | start no earlier than 2029-03-27 |
| 374 | 6.1.207 | Monthly Production Reports 207 | 1d | 2029-04-27 | 2029-04-27 | 2060d | start no earlier than 2029-04-27 |
| 375 | 6.1.208 | Monthly Production Reports 208 | 1d | 2029-05-28 | 2029-05-28 | 2039d | start no earlier than 2029-05-27 |
| 376 | 6.1.209 | Monthly Production Reports 209 | 1d | 2029-06-27 | 2029-06-27 | 2017d | start no earlier than 2029-06-27 |
| 377 | 6.1.210 | Monthly Production Reports 210 | 1d | 2029-07-27 | 2029-07-27 | 1995d | start no earlier than 2029-07-27 |
| 378 | 6.1.211 | Monthly Production Reports 211 | 1d | 2029-08-27 | 2029-08-27 | 1974d | start no earlier than 2029-08-27 |
| 379 | 6.1.212 | Monthly Production Reports 212 | 1d | 2029-09-27 | 2029-09-27 | 1951d | start no earlier than 2029-09-27 |
| 380 | 6.1.213 | Monthly Production Reports 213 | 1d | 2029-10-29 | 2029-10-29 | 1929d | start no earlier than 2029-10-27 |
| 381 | 6.1.214 | Monthly Production Reports 214 | 1d | 2029-11-27 | 2029-11-27 | 1908d | start no earlier than 2029-11-27 |
| 382 | 6.1.215 | Monthly Production Reports 215 | 1d | 2029-12-27 | 2029-12-27 | 1886d | start no earlier than 2029-12-27 |
| 383 | 6.1.216 | Monthly Production Reports 216 | 1d | 2030-01-28 | 2030-01-28 | 1864d | start no earlier than 2030-01-27 |
| 384 | 6.1.217 | Monthly Production Reports 217 | 1d | 2030-02-27 | 2030-02-27 | 1842d | start no earlier than 2030-02-27 |
| 385 | 6.1.218 | Monthly Production Reports 218 | 1d | 2030-03-27 | 2030-03-27 | 1822d | start no earlier than 2030-03-27 |
| 386 | 6.1.219 | Monthly Production Reports 219 | 1d | 2030-04-29 | 2030-04-29 | 1799d | start no earlier than 2030-04-27 |
| 387 | 6.1.220 | Monthly Production Reports 220 | 1d | 2030-05-27 | 2030-05-27 | 1779d | start no earlier than 2030-05-27 |
| 388 | 6.1.221 | Monthly Production Reports 221 | 1d | 2030-06-27 | 2030-06-27 | 1756d | start no earlier than 2030-06-27 |
| 389 | 6.1.222 | Monthly Production Reports 222 | 1d | 2030-07-29 | 2030-07-29 | 1734d | start no earlier than 2030-07-27 |
| 390 | 6.1.223 | Monthly Production Reports 223 | 1d | 2030-08-27 | 2030-08-27 | 1713d | start no earlier than 2030-08-27 |
| 391 | 6.1.224 | Monthly Production Reports 224 | 1d | 2030-09-27 | 2030-09-27 | 1690d | start no earlier than 2030-09-27 |
| 392 | 6.1.225 | Monthly Production Reports 225 | 1d | 2030-10-28 | 2030-10-28 | 1669d | start no earlier than 2030-10-27 |
| 393 | 6.1.226 | Monthly Production Reports 226 | 1d | 2030-11-27 | 2030-11-27 | 1647d | start no earlier than 2030-11-27 |
| 394 | 6.1.227 | Monthly Production Reports 227 | 1d | 2030-12-27 | 2030-12-27 | 1625d | start no earlier than 2030-12-27 |
| 395 | 6.1.228 | Monthly Production Reports 228 | 1d | 2031-01-27 | 2031-01-27 | 1604d | start no earlier than 2031-01-27 |
| 396 | 6.1.229 | Monthly Production Reports 229 | 1d | 2031-02-27 | 2031-02-27 | 1581d | start no earlier than 2031-02-27 |
| 397 | 6.1.230 | Monthly Production Reports 230 | 1d | 2031-03-27 | 2031-03-27 | 1561d | start no earlier than 2031-03-27 |
| 398 | 6.1.231 | Monthly Production Reports 231 | 1d | 2031-04-28 | 2031-04-28 | 1539d | start no earlier than 2031-04-27 |
| 399 | 6.1.232 | Monthly Production Reports 232 | 1d | 2031-05-27 | 2031-05-27 | 1518d | start no earlier than 2031-05-27 |
| 400 | 6.1.233 | Monthly Production Reports 233 | 1d | 2031-06-27 | 2031-06-27 | 1495d | start no earlier than 2031-06-27 |
| 401 | 6.1.234 | Monthly Production Reports 234 | 1d | 2031-07-28 | 2031-07-28 | 1474d | start no earlier than 2031-07-27 |
| 402 | 6.1.235 | Monthly Production Reports 235 | 1d | 2031-08-27 | 2031-08-27 | 1452d | start no earlier than 2031-08-27 |
| 403 | 6.1.236 | Monthly Production Reports 236 | 1d | 2031-09-29 | 2031-09-29 | 1429d | start no earlier than 2031-09-27 |
| 404 | 6.1.237 | Monthly Production Reports 237 | 1d | 2031-10-27 | 2031-10-27 | 1409d | start no earlier than 2031-10-27 |
| 405 | 6.1.238 | Monthly Production Reports 238 | 1d | 2031-11-27 | 2031-11-27 | 1386d | start no earlier than 2031-11-27 |
| 406 | 6.1.239 | Monthly Production Reports 239 | 1d | 2031-12-29 | 2031-12-29 | 1364d | start no earlier than 2031-12-27 |
| 407 | 6.1.240 | Monthly Production Reports 240 | 1d | 2032-01-27 | 2032-01-27 | 1343d | start no earlier than 2032-01-27 |
| 408 | 6.1.241 | Monthly Production Reports 241 | 1d | 2032-02-27 | 2032-02-27 | 1320d | start no earlier than 2032-02-27 |
| 409 | 6.1.242 | Monthly Production Reports 242 | 1d | 2032-03-29 | 2032-03-29 | 1299d | start no earlier than 2032-03-27 |
| 410 | 6.1.243 | Monthly Production Reports 243 | 1d | 2032-04-27 | 2032-04-27 | 1278d | start no earlier than 2032-04-27 |
| 411 | 6.1.244 | Monthly Production Reports 244 | 1d | 2032-05-27 | 2032-05-27 | 1256d | start no earlier than 2032-05-27 |
| 412 | 6.1.245 | Monthly Production Reports 245 | 1d | 2032-06-28 | 2032-06-28 | 1234d | start no earlier than 2032-06-27 |
| 413 | 6.1.246 | Monthly Production Reports 246 | 1d | 2032-07-27 | 2032-07-27 | 1213d | start no earlier than 2032-07-27 |
| 414 | 6.1.247 | Monthly Production Reports 247 | 1d | 2032-08-27 | 2032-08-27 | 1190d | start no earlier than 2032-08-27 |
| 415 | 6.1.248 | Monthly Production Reports 248 | 1d | 2032-09-27 | 2032-09-27 | 1169d | start no earlier than 2032-09-27 |
| 416 | 6.1.249 | Monthly Production Reports 249 | 1d | 2032-10-27 | 2032-10-27 | 1147d | start no earlier than 2032-10-27 |
| 417 | 6.1.250 | Monthly Production Reports 250 | 1d | 2032-11-29 | 2032-11-29 | 1124d | start no earlier than 2032-11-27 |
| 418 | 6.1.251 | Monthly Production Reports 251 | 1d | 2032-12-27 | 2032-12-27 | 1104d | start no earlier than 2032-12-27 |
| 419 | 6.1.252 | Monthly Production Reports 252 | 1d | 2033-01-27 | 2033-01-27 | 1081d | start no earlier than 2033-01-27 |
| 420 | 6.1.253 | Monthly Production Reports 253 | 1d | 2033-02-28 | 2033-02-28 | 1059d | start no earlier than 2033-02-27 |
| 421 | 6.1.254 | Monthly Production Reports 254 | 1d | 2033-03-28 | 2033-03-28 | 1039d | start no earlier than 2033-03-27 |
| 422 | 6.1.255 | Monthly Production Reports 255 | 1d | 2033-04-27 | 2033-04-27 | 1017d | start no earlier than 2033-04-27 |
| 423 | 6.1.256 | Monthly Production Reports 256 | 1d | 2033-05-27 | 2033-05-27 | 995d | start no earlier than 2033-05-27 |
| 424 | 6.1.257 | Monthly Production Reports 257 | 1d | 2033-06-27 | 2033-06-27 | 974d | start no earlier than 2033-06-27 |
| 425 | 6.1.258 | Monthly Production Reports 258 | 1d | 2033-07-27 | 2033-07-27 | 952d | start no earlier than 2033-07-27 |
| 426 | 6.1.259 | Monthly Production Reports 259 | 1d | 2033-08-29 | 2033-08-29 | 929d | start no earlier than 2033-08-27 |
| 427 | 6.1.260 | Monthly Production Reports 260 | 1d | 2033-09-27 | 2033-09-27 | 908d | start no earlier than 2033-09-27 |
| 428 | 6.1.261 | Monthly Production Reports 261 | 1d | 2033-10-27 | 2033-10-27 | 886d | start no earlier than 2033-10-27 |

| ID | WBS | Task | Duration | Start | Finish | Total slack | Constraint |
| --- | --- | --- | --- | --- | --- | --- | --- |
| 429 | 6.1.262 | Monthly Production Reports 262 | 1d | 2033-11-28 | 2033-11-28 | 864d | start no earlier than 2033-11-27 |
| 430 | 6.1.263 | Monthly Production Reports 263 | 1d | 2033-12-27 | 2033-12-27 | 843d | start no earlier than 2033-12-27 |
| 431 | 6.1.264 | Monthly Production Reports 264 | 1d | 2034-01-27 | 2034-01-27 | 820d | start no earlier than 2034-01-27 |
| 432 | 6.1.265 | Monthly Production Reports 265 | 1d | 2034-02-27 | 2034-02-27 | 799d | start no earlier than 2034-02-27 |
| 433 | 6.1.266 | Monthly Production Reports 266 | 1d | 2034-03-27 | 2034-03-27 | 779d | start no earlier than 2034-03-27 |
| 434 | 6.1.267 | Monthly Production Reports 267 | 1d | 2034-04-27 | 2034-04-27 | 756d | start no earlier than 2034-04-27 |
| 435 | 6.1.268 | Monthly Production Reports 268 | 1d | 2034-05-29 | 2034-05-29 | 734d | start no earlier than 2034-05-27 |
| 436 | 6.1.269 | Monthly Production Reports 269 | 1d | 2034-06-27 | 2034-06-27 | 713d | start no earlier than 2034-06-27 |
| 437 | 6.1.270 | Monthly Production Reports 270 | 1d | 2034-07-27 | 2034-07-27 | 691d | start no earlier than 2034-07-27 |
| 438 | 6.1.271 | Monthly Production Reports 271 | 1d | 2034-08-28 | 2034-08-28 | 669d | start no earlier than 2034-08-27 |
| 439 | 6.1.272 | Monthly Production Reports 272 | 1d | 2034-09-27 | 2034-09-27 | 647d | start no earlier than 2034-09-27 |
| 440 | 6.1.273 | Monthly Production Reports 273 | 1d | 2034-10-27 | 2034-10-27 | 625d | start no earlier than 2034-10-27 |
| 441 | 6.1.274 | Monthly Production Reports 274 | 1d | 2034-11-27 | 2034-11-27 | 604d | start no earlier than 2034-11-27 |
| 442 | 6.1.275 | Monthly Production Reports 275 | 1d | 2034-12-27 | 2034-12-27 | 582d | start no earlier than 2034-12-27 |
| 443 | 6.1.276 | Monthly Production Reports 276 | 1d | 2035-01-29 | 2035-01-29 | 559d | start no earlier than 2035-01-27 |
| 444 | 6.1.277 | Monthly Production Reports 277 | 1d | 2035-02-27 | 2035-02-27 | 538d | start no earlier than 2035-02-27 |
| 445 | 6.1.278 | Monthly Production Reports 278 | 1d | 2035-03-27 | 2035-03-27 | 518d | start no earlier than 2035-03-27 |
| 446 | 6.1.279 | Monthly Production Reports 279 | 1d | 2035-04-27 | 2035-04-27 | 495d | start no earlier than 2035-04-27 |
| 447 | 6.1.280 | Monthly Production Reports 280 | 1d | 2035-05-28 | 2035-05-28 | 474d | start no earlier than 2035-05-27 |
| 448 | 6.1.281 | Monthly Production Reports 281 | 1d | 2035-06-27 | 2035-06-27 | 452d | start no earlier than 2035-06-27 |
| 449 | 6.1.282 | Monthly Production Reports 282 | 1d | 2035-07-27 | 2035-07-27 | 430d | start no earlier than 2035-07-27 |
| 450 | 6.1.283 | Monthly Production Reports 283 | 1d | 2035-08-27 | 2035-08-27 | 409d | start no earlier than 2035-08-27 |
| 451 | 6.1.284 | Monthly Production Reports 284 | 1d | 2035-09-27 | 2035-09-27 | 386d | start no earlier than 2035-09-27 |
| 452 | 6.1.285 | Monthly Production Reports 285 | 1d | 2035-10-29 | 2035-10-29 | 364d | start no earlier than 2035-10-27 |
| 453 | 6.1.286 | Monthly Production Reports 286 | 1d | 2035-11-27 | 2035-11-27 | 343d | start no earlier than 2035-11-27 |
| 454 | 6.1.287 | Monthly Production Reports 287 | 1d | 2035-12-27 | 2035-12-27 | 321d | start no earlier than 2035-12-27 |
| 455 | 6.1.288 | Monthly Production Reports 288 | 1d | 2036-01-28 | 2036-01-28 | 299d | start no earlier than 2036-01-27 |
| 456 | 6.1.289 | Monthly Production Reports 289 | 1d | 2036-02-27 | 2036-02-27 | 277d | start no earlier than 2036-02-27 |
| 457 | 6.1.290 | Monthly Production Reports 290 | 1d | 2036-03-27 | 2036-03-27 | 256d | start no earlier than 2036-03-27 |
| 458 | 6.1.291 | Monthly Production Reports 291 | 1d | 2036-04-28 | 2036-04-28 | 234d | start no earlier than 2036-04-27 |
| 459 | 6.1.292 | Monthly Production Reports 292 | 1d | 2036-05-27 | 2036-05-27 | 213d | start no earlier than 2036-05-27 |
| 460 | 6.1.293 | Monthly Production Reports 293 | 1d | 2036-06-27 | 2036-06-27 | 190d | start no earlier than 2036-06-27 |
| 461 | 6.1.294 | Monthly Production Reports 294 | 1d | 2036-07-28 | 2036-07-28 | 169d | start no earlier than 2036-07-27 |
| 462 | 6.1.295 | Monthly Production Reports 295 | 1d | 2036-08-27 | 2036-08-27 | 147d | start no earlier than 2036-08-27 |
| 463 | 6.1.296 | Monthly Production Reports 296 | 1d | 2036-09-29 | 2036-09-29 | 124d | start no earlier than 2036-09-27 |
| 464 | 6.1.297 | Monthly Production Reports 297 | 1d | 2036-10-27 | 2036-10-27 | 104d | start no earlier than 2036-10-27 |
| 465 | 6.1.298 | Monthly Production Reports 298 | 1d | 2036-11-27 | 2036-11-27 | 81d | start no earlier than 2036-11-27 |
| 466 | 6.1.299 | Monthly Production Reports 299 | 1d | 2036-12-29 | 2036-12-29 | 59d | start no earlier than 2036-12-27 |
| 467 | 6.1.300 | Monthly Production Reports 300 | 1d | 2037-01-27 | 2037-01-27 | 38d | start no earlier than 2037-01-27 |
| 468 | 6.1.301 | Monthly Production Reports 301 | 1d | 2037-02-27 | 2037-02-27 | 15d | start no earlier than 2037-02-27 |

| ID | WBS | Task | Type | Duration | Start | Finish | Predecessors | Total slack | Constraint | Resources | Work |
| --- | --- | --- | --- | --- | --- | --- | --- | --- | --- | --- | --- |
| 469 | 6.2 | **Quarterly Reports (Safety, Environment, Resource)** |  | 4967d | 2018-03-07 | 2037-03-23 | 164 | 0d |  | Proponent | 39736h |
| 470 | 6.2.1 | Quarterly Reports (Safety, Environment, Resource) 1 | milestone | 0d | 2018-03-07 | 2018-03-07 |  | 4967d | start no earlier than 2012-06-25 |  |  |
| 471 | 6.2.2 | Quarterly Reports (Safety, Environment, Resource) 2 | milestone | 0d | 2018-03-07 | 2018-03-07 |  | 4967d | start no earlier than 2012-09-24 |  |  |
| 472 | 6.2.3 | Quarterly Reports (Safety, Environment, Resource) 3 | milestone | 0d | 2018-03-07 | 2018-03-07 |  | 4967d | start no earlier than 2012-12-24 |  |  |
| 473 | 6.2.4 | Quarterly Reports (Safety, Environment, Resource) 4 | milestone | 0d | 2018-03-07 | 2018-03-07 |  | 4967d | start no earlier than 2013-03-25 |  |  |
| 474 | 6.2.5 | Quarterly Reports (Safety, Environment, Resource) 5 | milestone | 0d | 2018-03-07 | 2018-03-07 |  | 4967d | start no earlier than 2013-06-24 |  |  |
| 475 | 6.2.6 | Quarterly Reports (Safety, Environment, Resource) 6 | milestone | 0d | 2018-03-07 | 2018-03-07 |  | 4967d | start no earlier than 2013-09-23 |  |  |
| 476 | 6.2.7 | Quarterly Reports (Safety, Environment, Resource) 7 | milestone | 0d | 2018-03-07 | 2018-03-07 |  | 4967d | start no earlier than 2013-12-23 |  |  |
| 477 | 6.2.8 | Quarterly Reports (Safety, Environment, Resource) 8 | milestone | 0d | 2018-03-07 | 2018-03-07 |  | 4967d | start no earlier than 2014-03-24 |  |  |
| 478 | 6.2.9 | Quarterly Reports (Safety, Environment, Resource) 9 | milestone | 0d | 2018-03-07 | 2018-03-07 |  | 4967d | start no earlier than 2014-06-23 |  |  |
| 479 | 6.2.10 | Quarterly Reports (Safety, Environment, Resource) 10 | milestone | 0d | 2018-03-07 | 2018-03-07 |  | 4967d | start no earlier than 2014-09-22 |  |  |
| 480 | 6.2.11 | Quarterly Reports (Safety, Environment, Resource) 11 | milestone | 0d | 2018-03-07 | 2018-03-07 |  | 4967d | start no earlier than 2014-12-22 |  |  |
| 481 | 6.2.12 | Quarterly Reports (Safety, Environment, Resource) 12 | milestone | 0d | 2018-03-07 | 2018-03-07 |  | 4967d | start no earlier than 2015-03-23 |  |  |
| 482 | 6.2.13 | Quarterly Reports (Safety, Environment, Resource) 13 | milestone | 0d | 2018-03-07 | 2018-03-07 |  | 4967d | start no earlier than 2015-06-22 |  |  |
| 483 | 6.2.14 | Quarterly Reports (Safety, Environment, Resource) 14 | milestone | 0d | 2018-03-07 | 2018-03-07 |  | 4967d | start no earlier than 2015-09-28 |  |  |
| 484 | 6.2.15 | Quarterly Reports (Safety, Environment, Resource) 15 | milestone | 0d | 2018-03-07 | 2018-03-07 |  | 4967d | start no earlier than 2015-12-28 |  |  |
| 485 | 6.2.16 | Quarterly Reports (Safety, Environment, Resource) 16 | milestone | 0d | 2018-03-07 | 2018-03-07 |  | 4967d | start no earlier than 2016-03-28 |  |  |
| 486 | 6.2.17 | Quarterly Reports (Safety, Environment, Resource) 17 | milestone | 0d | 2018-03-07 | 2018-03-07 |  | 4967d | start no earlier than 2016-06-27 |  |  |
| 487 | 6.2.18 | Quarterly Reports (Safety, Environment, Resource) 18 | milestone | 0d | 2018-03-07 | 2018-03-07 |  | 4967d | start no earlier than 2016-09-26 |  |  |
| 488 | 6.2.19 | Quarterly Reports (Safety, Environment, Resource) 19 | milestone | 0d | 2018-03-07 | 2018-03-07 |  | 4967d | start no earlier than 2016-12-26 |  |  |
| 489 | 6.2.20 | Quarterly Reports (Safety, Environment, Resource) 20 | milestone | 0d | 2018-03-07 | 2018-03-07 |  | 4967d | start no earlier than 2017-03-27 |  |  |
| 490 | 6.2.21 | Quarterly Reports (Safety, Environment, Resource) 21 | milestone | 0d | 2018-03-07 | 2018-03-07 |  | 4967d | start no earlier than 2017-06-26 |  |  |
| 491 | 6.2.22 | Quarterly Reports (Safety, Environment, Resource) 22 | milestone | 0d | 2018-03-07 | 2018-03-07 |  | 4967d | start no earlier than 2017-09-25 |  |  |
| 492 | 6.2.23 | Quarterly Reports (Safety, Environment, Resource) 23 | milestone | 0d | 2018-03-07 | 2018-03-07 |  | 4967d | start no earlier than 2017-12-25 |  |  |
| 493 | 6.2.24 | Quarterly Reports (Safety, Environment, Resource) 24 | milestone | 0d | 2018-03-26 | 2018-03-26 |  | 4955d | start no earlier than 2018-03-26 |  |  |
| 494 | 6.2.25 | Quarterly Reports (Safety, Environment, Resource) 25 | milestone | 0d | 2018-06-25 | 2018-06-25 |  | 4890d | start no earlier than 2018-06-25 |  |  |
| 495 | 6.2.26 | Quarterly Reports (Safety, Environment, Resource) 26 | milestone | 0d | 2018-09-24 | 2018-09-24 |  | 4825d | start no earlier than 2018-09-24 |  |  |
| 496 | 6.2.27 | Quarterly Reports (Safety, Environment, Resource) 27 | milestone | 0d | 2018-12-24 | 2018-12-24 |  | 4760d | start no earlier than 2018-12-24 |  |  |
| 497 | 6.2.28 | Quarterly Reports (Safety, Environment, Resource) 28 | milestone | 0d | 2019-03-25 | 2019-03-25 |  | 4695d | start no earlier than 2019-03-25 |  |  |
| 498 | 6.2.29 | Quarterly Reports (Safety, Environment, Resource) 29 | milestone | 0d | 2019-06-24 | 2019-06-24 |  | 4630d | start no earlier than 2019-06-24 |  |  |
| 499 | 6.2.30 | Quarterly Reports (Safety, Environment, Resource) 30 | milestone | 0d | 2019-09-23 | 2019-09-23 |  | 4565d | start no earlier than 2019-09-23 |  |  |
| 500 | 6.2.31 | Quarterly Reports (Safety, Environment, Resource) 31 | milestone | 0d | 2019-12-23 | 2019-12-23 |  | 4500d | start no earlier than 2019-12-23 |  |  |
| 501 | 6.2.32 | Quarterly Reports (Safety, Environment, Resource) 32 | milestone | 0d | 2020-03-23 | 2020-03-23 |  | 4435d | start no earlier than 2020-03-23 |  |  |
| 502 | 6.2.33 | Quarterly Reports (Safety, Environment, Resource) 33 | milestone | 0d | 2020-06-22 | 2020-06-22 |  | 4370d | start no earlier than 2020-06-22 |  |  |
| 503 | 6.2.34 | Quarterly Reports (Safety, Environment, Resource) 34 | milestone | 0d | 2020-09-28 | 2020-09-28 |  | 4300d | start no earlier than 2020-09-28 |  |  |
| 504 | 6.2.35 | Quarterly Reports (Safety, Environment, Resource) 35 | milestone | 0d | 2020-12-28 | 2020-12-28 |  | 4235d | start no earlier than 2020-12-28 |  |  |
| 505 | 6.2.36 | Quarterly Reports (Safety, Environment, Resource) 36 | milestone | 0d | 2021-03-22 | 2021-03-22 |  | 4175d | start no earlier than 2021-03-22 |  |  |
| 506 | 6.2.37 | Quarterly Reports (Safety, Environment, Resource) 37 | milestone | 0d | 2021-06-28 | 2021-06-28 |  | 4105d | start no earlier than 2021-06-28 |  |  |
| 507 | 6.2.38 | Quarterly Reports (Safety, Environment, Resource) 38 | milestone | 0d | 2021-09-27 | 2021-09-27 |  | 4040d | start no earlier than 2021-09-27 |  |  |
| 508 | 6.2.39 | Quarterly Reports (Safety, Environment, Resource) 39 | milestone | 0d | 2021-12-27 | 2021-12-27 |  | 3975d | start no earlier than 2021-12-27 |  |  |
| 509 | 6.2.40 | Quarterly Reports (Safety, Environment, Resource) 40 | milestone | 0d | 2022-03-28 | 2022-03-28 |  | 3910d | start no earlier than 2022-03-28 |  |  |
| 510 | 6.2.41 | Quarterly Reports (Safety, Environment, Resource) 41 | milestone | 0d | 2022-06-27 | 2022-06-27 |  | 3845d | start no earlier than 2022-06-27 |  |  |
| 511 | 6.2.42 | Quarterly Reports (Safety, Environment, Resource) 42 | milestone | 0d | 2022-09-26 | 2022-09-26 |  | 3780d | start no earlier than 2022-09-26 |  |  |
| 512 | 6.2.43 | Quarterly Reports (Safety, Environment, Resource) 43 | milestone | 0d | 2022-12-26 | 2022-12-26 |  | 3715d | start no earlier than 2022-12-26 |  |  |
| 513 | 6.2.44 | Quarterly Reports (Safety, Environment, Resource) 44 | milestone | 0d | 2023-03-27 | 2023-03-27 |  | 3650d | start no earlier than 2023-03-27 |  |  |
| 514 | 6.2.45 | Quarterly Reports (Safety, Environment, Resource) 45 | milestone | 0d | 2023-06-26 | 2023-06-26 |  | 3585d | start no earlier than 2023-06-26 |  |  |
| 515 | 6.2.46 | Quarterly Reports (Safety, Environment, Resource) 46 | milestone | 0d | 2023-09-25 | 2023-09-25 |  | 3520d | start no earlier than 2023-09-25 |  |  |
| 516 | 6.2.47 | Quarterly Reports (Safety, Environment, Resource) 47 | milestone | 0d | 2023-12-25 | 2023-12-25 |  | 3455d | start no earlier than 2023-12-25 |  |  |
| 517 | 6.2.48 | Quarterly Reports (Safety, Environment, Resource) 48 | milestone | 0d | 2024-03-25 | 2024-03-25 |  | 3390d | start no earlier than 2024-03-25 |  |  |
| 518 | 6.2.49 | Quarterly Reports (Safety, Environment, Resource) 49 | milestone | 0d | 2024-06-24 | 2024-06-24 |  | 3325d | start no earlier than 2024-06-24 |  |  |
| 519 | 6.2.50 | Quarterly Reports (Safety, Environment, Resource) 50 | milestone | 0d | 2024-09-23 | 2024-09-23 |  | 3260d | start no earlier than 2024-09-23 |  |  |
| 520 | 6.2.51 | Quarterly Reports (Safety, Environment, Resource) 51 | milestone | 0d | 2024-12-23 | 2024-12-23 |  | 3195d | start no earlier than 2024-12-23 |  |  |
| 521 | 6.2.52 | Quarterly Reports (Safety, Environment, Resource) 52 | milestone | 0d | 2025-03-24 | 2025-03-24 |  | 3130d | start no earlier than 2025-03-24 |  |  |
| 522 | 6.2.53 | Quarterly Reports (Safety, Environment, Resource) 53 | milestone | 0d | 2025-06-23 | 2025-06-23 |  | 3065d | start no earlier than 2025-06-23 |  |  |
| 523 | 6.2.54 | Quarterly Reports (Safety, Environment, Resource) 54 | milestone | 0d | 2025-09-22 | 2025-09-22 |  | 3000d | start no earlier than 2025-09-22 |  |  |
| 524 | 6.2.55 | Quarterly Reports (Safety, Environment, Resource) 55 | milestone | 0d | 2025-12-22 | 2025-12-22 |  | 2935d | start no earlier than 2025-12-22 |  |  |
| 525 | 6.2.56 | Quarterly Reports (Safety, Environment, Resource) 56 | milestone | 0d | 2026-03-23 | 2026-03-23 |  | 2870d | start no earlier than 2026-03-23 |  |  |
| 526 | 6.2.57 | Quarterly Reports (Safety, Environment, Resource) 57 | milestone | 0d | 2026-06-22 | 2026-06-22 |  | 2805d | start no earlier than 2026-06-22 |  |  |
| 527 | 6.2.58 | Quarterly Reports (Safety, Environment, Resource) 58 | milestone | 0d | 2026-09-28 | 2026-09-28 |  | 2735d | start no earlier than 2026-09-28 |  |  |
| 528 | 6.2.59 | Quarterly Reports (Safety, Environment, Resource) 59 | milestone | 0d | 2026-12-28 | 2026-12-28 |  | 2670d | start no earlier than 2026-12-28 |  |  |
| 529 | 6.2.60 | Quarterly Reports (Safety, Environment, Resource) 60 | milestone | 0d | 2027-03-22 | 2027-03-22 |  | 2610d | start no earlier than 2027-03-22 |  |  |
| 530 | 6.2.61 | Quarterly Reports (Safety, Environment, Resource) 61 | milestone | 0d | 2027-06-28 | 2027-06-28 |  | 2540d | start no earlier than 2027-06-28 |  |  |
| 531 | 6.2.62 | Quarterly Reports (Safety, Environment, Resource) 62 | milestone | 0d | 2027-09-27 | 2027-09-27 |  | 2475d | start no earlier than 2027-09-27 |  |  |
| 532 | 6.2.63 | Quarterly Reports (Safety, Environment, Resource) 63 | milestone | 0d | 2027-12-27 | 2027-12-27 |  | 2410d | start no earlier than 2027-12-27 |  |  |
| 533 | 6.2.64 | Quarterly Reports (Safety, Environment, Resource) 64 | milestone | 0d | 2028-03-27 | 2028-03-27 |  | 2345d | start no earlier than 2028-03-27 |  |  |
| 534 | 6.2.65 | Quarterly Reports (Safety, Environment, Resource) 65 | milestone | 0d | 2028-06-26 | 2028-06-26 |  | 2280d | start no earlier than 2028-06-26 |  |  |
| 535 | 6.2.66 | Quarterly Reports (Safety, Environment, Resource) 66 | milestone | 0d | 2028-09-25 | 2028-09-25 |  | 2215d | start no earlier than 2028-09-25 |  |  |
| 536 | 6.2.67 | Quarterly Reports (Safety, Environment, Resource) 67 | milestone | 0d | 2028-12-25 | 2028-12-25 |  | 2150d | start no earlier than 2028-12-25 |  |  |
| 537 | 6.2.68 | Quarterly Reports (Safety, Environment, Resource) 68 | milestone | 0d | 2029-03-26 | 2029-03-26 |  | 2085d | start no earlier than 2029-03-26 |  |  |
| 538 | 6.2.69 | Quarterly Reports (Safety, Environment, Resource) 69 | milestone | 0d | 2029-06-25 | 2029-06-25 |  | 2020d | start no earlier than 2029-06-25 |  |  |

Notes:
- 469: submitted quarterly to DMP

| ID | WBS | Task | Type | Duration | Start | Finish | Total slack | Constraint |
| --- | --- | --- | --- | --- | --- | --- | --- | --- |
| 539 | 6.2.70 | Quarterly Reports (Safety, Environment, Resource) 70 | milestone | 0d | 2029-09-24 | 2029-09-24 | 1955d | start no earlier than 2029-09-24 |
| 540 | 6.2.71 | Quarterly Reports (Safety, Environment, Resource) 71 | milestone | 0d | 2029-12-24 | 2029-12-24 | 1890d | start no earlier than 2029-12-24 |
| 541 | 6.2.72 | Quarterly Reports (Safety, Environment, Resource) 72 | milestone | 0d | 2030-03-25 | 2030-03-25 | 1825d | start no earlier than 2030-03-25 |
| 542 | 6.2.73 | Quarterly Reports (Safety, Environment, Resource) 73 | milestone | 0d | 2030-06-24 | 2030-06-24 | 1760d | start no earlier than 2030-06-24 |
| 543 | 6.2.74 | Quarterly Reports (Safety, Environment, Resource) 74 | milestone | 0d | 2030-09-23 | 2030-09-23 | 1695d | start no earlier than 2030-09-23 |
| 544 | 6.2.75 | Quarterly Reports (Safety, Environment, Resource) 75 | milestone | 0d | 2030-12-23 | 2030-12-23 | 1630d | start no earlier than 2030-12-23 |
| 545 | 6.2.76 | Quarterly Reports (Safety, Environment, Resource) 76 | milestone | 0d | 2031-03-24 | 2031-03-24 | 1565d | start no earlier than 2031-03-24 |
| 546 | 6.2.77 | Quarterly Reports (Safety, Environment, Resource) 77 | milestone | 0d | 2031-06-23 | 2031-06-23 | 1500d | start no earlier than 2031-06-23 |
| 547 | 6.2.78 | Quarterly Reports (Safety, Environment, Resource) 78 | milestone | 0d | 2031-09-22 | 2031-09-22 | 1435d | start no earlier than 2031-09-22 |
| 548 | 6.2.79 | Quarterly Reports (Safety, Environment, Resource) 79 | milestone | 0d | 2031-12-22 | 2031-12-22 | 1370d | start no earlier than 2031-12-22 |
| 549 | 6.2.80 | Quarterly Reports (Safety, Environment, Resource) 80 | milestone | 0d | 2032-03-22 | 2032-03-22 | 1305d | start no earlier than 2032-03-22 |
| 550 | 6.2.81 | Quarterly Reports (Safety, Environment, Resource) 81 | milestone | 0d | 2032-06-28 | 2032-06-28 | 1235d | start no earlier than 2032-06-28 |
| 551 | 6.2.82 | Quarterly Reports (Safety, Environment, Resource) 82 | milestone | 0d | 2032-09-27 | 2032-09-27 | 1170d | start no earlier than 2032-09-27 |
| 552 | 6.2.83 | Quarterly Reports (Safety, Environment, Resource) 83 | milestone | 0d | 2032-12-27 | 2032-12-27 | 1105d | start no earlier than 2032-12-27 |
| 553 | 6.2.84 | Quarterly Reports (Safety, Environment, Resource) 84 | milestone | 0d | 2033-03-28 | 2033-03-28 | 1040d | start no earlier than 2033-03-28 |
| 554 | 6.2.85 | Quarterly Reports (Safety, Environment, Resource) 85 | milestone | 0d | 2033-06-27 | 2033-06-27 | 975d | start no earlier than 2033-06-27 |
| 555 | 6.2.86 | Quarterly Reports (Safety, Environment, Resource) 86 | milestone | 0d | 2033-09-26 | 2033-09-26 | 910d | start no earlier than 2033-09-26 |
| 556 | 6.2.87 | Quarterly Reports (Safety, Environment, Resource) 87 | milestone | 0d | 2033-12-26 | 2033-12-26 | 845d | start no earlier than 2033-12-26 |
| 557 | 6.2.88 | Quarterly Reports (Safety, Environment, Resource) 88 | milestone | 0d | 2034-03-27 | 2034-03-27 | 780d | start no earlier than 2034-03-27 |
| 558 | 6.2.89 | Quarterly Reports (Safety, Environment, Resource) 89 | milestone | 0d | 2034-06-26 | 2034-06-26 | 715d | start no earlier than 2034-06-26 |
| 559 | 6.2.90 | Quarterly Reports (Safety, Environment, Resource) 90 | milestone | 0d | 2034-09-25 | 2034-09-25 | 650d | start no earlier than 2034-09-25 |
| 560 | 6.2.91 | Quarterly Reports (Safety, Environment, Resource) 91 | milestone | 0d | 2034-12-25 | 2034-12-25 | 585d | start no earlier than 2034-12-25 |
| 561 | 6.2.92 | Quarterly Reports (Safety, Environment, Resource) 92 | milestone | 0d | 2035-03-26 | 2035-03-26 | 520d | start no earlier than 2035-03-26 |
| 562 | 6.2.93 | Quarterly Reports (Safety, Environment, Resource) 93 | milestone | 0d | 2035-06-25 | 2035-06-25 | 455d | start no earlier than 2035-06-25 |
| 563 | 6.2.94 | Quarterly Reports (Safety, Environment, Resource) 94 | milestone | 0d | 2035-09-24 | 2035-09-24 | 390d | start no earlier than 2035-09-24 |
| 564 | 6.2.95 | Quarterly Reports (Safety, Environment, Resource) 95 | milestone | 0d | 2035-12-24 | 2035-12-24 | 325d | start no earlier than 2035-12-24 |
| 565 | 6.2.96 | Quarterly Reports (Safety, Environment, Resource) 96 | milestone | 0d | 2036-03-24 | 2036-03-24 | 260d | start no earlier than 2036-03-24 |
| 566 | 6.2.97 | Quarterly Reports (Safety, Environment, Resource) 97 | milestone | 0d | 2036-06-23 | 2036-06-23 | 195d | start no earlier than 2036-06-23 |
| 567 | 6.2.98 | Quarterly Reports (Safety, Environment, Resource) 98 | milestone | 0d | 2036-09-22 | 2036-09-22 | 130d | start no earlier than 2036-09-22 |
| 568 | 6.2.99 | Quarterly Reports (Safety, Environment, Resource) 99 | milestone | 0d | 2036-12-22 | 2036-12-22 | 65d | start no earlier than 2036-12-22 |
| 569 | 6.2.100 | Quarterly Reports (Safety, Environment, Resource) 100 | milestone | 0d | 2037-03-23 | 2037-03-23 | 0d | start no earlier than 2037-03-23 |

| ID | WBS | Task | Type | Duration | Start | Finish | Predecessors | Total slack | Free slack | Constraint | Resources | Work |
| --- | --- | --- | --- | --- | --- | --- | --- | --- | --- | --- | --- | --- |
| 570 | 6.3 | **Field Development Plan** |  | 3915d | 2021-02-22 | 2036-02-25 |  | 280d |  |  | DMP PD | 31320h |
| 571 | 6.3.1 | Field Development Plan 5 year | milestone | 0d | 2021-02-22 | 2021-02-22 |  | 4195d |  | start no earlier than 2021-02-22 | DMP PD |  |
| 572 | 6.3.2 | Field Development Plan 10 year | milestone | 0d | 2026-02-23 | 2026-02-23 |  | 2890d |  | start no earlier than 2026-02-23 | DMP PD |  |
| 573 | 6.3.3 | Field Development Plan 15 year | milestone | 0d | 2031-02-24 | 2031-02-24 |  | 1585d |  | start no earlier than 2031-02-24 | DMP PD |  |
| 574 | 6.3.4 | Field Development Plan 20 year | milestone | 0d | 2036-02-25 | 2036-02-25 |  | -29d | 0d | start no earlier than 2036-02-25 | DMP PD |  |
| 575 | 6.4 | **Safety Case** |  | 3915d | 2021-02-22 | 2036-02-25 |  | 280d |  |  | DMP RSD | 31320h |
| 576 | 6.4.1 | Safety Case 5 year | milestone | 0d | 2021-02-22 | 2021-02-22 |  | 4195d |  | start no earlier than 2021-02-22 | DMP RSD |  |
| 577 | 6.4.2 | Safety Case 10 year | milestone | 0d | 2026-02-23 | 2026-02-23 |  | 2890d |  | start no earlier than 2026-02-23 | DMP RSD |  |
| 578 | 6.4.3 | Safety Case 15 year | milestone | 0d | 2031-02-24 | 2031-02-24 |  | 1585d |  | start no earlier than 2031-02-24 | DMP RSD |  |
| 579 | 6.4.4 | Safety Case 20 year | milestone | 0d | 2036-02-25 | 2036-02-25 |  | -29d | 0d | start no earlier than 2036-02-25 | DMP RSD |  |
| 580 | 6.5 | **Environment Plans** |  | 3915d | 2021-02-22 | 2036-02-25 |  | 280d |  |  | DMP ED | 31320h |
| 581 | 6.5.1 | Environment Plans 5 year | milestone | 0d | 2021-02-22 | 2021-02-22 |  | 4195d |  | start no earlier than 2021-02-22 | DMP ED |  |
| 582 | 6.5.2 | Environment Plans 10 year | milestone | 0d | 2026-02-23 | 2026-02-23 |  | 2890d |  | start no earlier than 2026-02-23 | DMP ED |  |
| 583 | 6.5.3 | Environment Plans 15 year | milestone | 0d | 2031-02-24 | 2031-02-24 |  | 1585d |  | start no earlier than 2031-02-24 | DMP ED |  |
| 584 | 6.5.4 | Environment Plans 20 year | milestone | 0d | 2036-02-25 | 2036-02-25 |  | -29d | 0d | start no earlier than 2036-02-25 | DMP ED |  |
| 585 | 7 | **CLOSURE APPROVALS** |  | 6291d? | 2012-02-27 | 2036-04-07 |  |  |  |  |  | 1688h |
| 586 | 7.1 | **Field Abandonment Plan** |  | 30d | 2036-02-25 | 2036-04-04 | 584, 579, 574 | -29d | 0d |  |  | 1440h |
| 587 | 7.1.1 | Safety Case |  | 30d | 2036-02-25 | 2036-04-04 | 584, 579, 574 | 0d |  |  | DMP RSD | 240h |
| 588 | 7.1.2 | Environment Plans |  | 30d | 2036-02-25 | 2036-04-04 | 584, 579, 574 | 0d |  |  | DMP ED | 240h |
| 589 | 7.1.3 | WOMP & Plug and Abandonment Plan |  | 30d | 2036-02-25 | 2036-04-04 | 584, 579, 574 | 0d |  |  | DMP PD | 240h |
| 590 | 7.1.4 | Decommissioning Plan |  | 30d | 2036-02-25 | 2036-04-04 | 584, 579, 574 | 0d |  |  | DMP PD | 240h |
| 591 | 7.1.5 | Removal of Surface Facilities & Pipeline Rehabilitation |  | 30d | 2036-02-25 | 2036-04-04 | 584, 579, 574 | 0d |  |  | DMP PD | 240h |
| 592 | 7.1.6 | Land Rehabilitation |  | 30d | 2036-02-25 | 2036-04-04 | 584, 579, 574 | -29d | 0d |  | DMP ED | 240h |
| 593 | 7.2 | Contaminated Sites Clearance |  | 30d | 2036-04-07 | 2036-05-16 | 592 | -29d | 0d |  | DEC | 240h |
| 594 | 7.3 | Surrender |  | 1d | 2036-04-07 | 2036-04-07 | 586 | 0d |  |  | DMP PD | 8h |

Notes:
- 570: updated every 5 years
- 575: updated every 5 years
- 580: updated every 5 years
